# RTWC

Schedule from MS Project, 2015-01-05 to 2022-11-18, costs in CHF, A marks actual dates.
CERN

## Calendars

- CERN calendar: Mon-Fri 08:00-12:00, 13:00-17:00; Sat-Sun off. Exceptions (off unless hours are given): 2015-04-03 (Vendredi saint'15), 2015-04-06 (Lundi de paques'15), 2015-05-01 (Fete du travail'15), 2015-05-14 (Ascension'15), 2015-05-25 (Lundi de Pentecote'15), 2015-09-10 (Jeune genevois'15), 2015-12-21 to 2016-01-01 (Noel'15), 2016-03-25 (Vendredi saint'16), 2016-03-28 (Lundi de paques'16), 2016-05-05 (Fete du travail'16), 2016-05-06 (Ascension'16), 2016-05-16 (Lundi de pentecote'16), 2016-09-08 (Jeune genevois), 2016-12-22 to 2017-01-04 (Noel'16), 2017-04-14 (Vendredi saint'17), 2017-04-17 (Lundi de paques'17), 2017-05-01 (Fete du travail'17), 2017-05-25 (Ascension'17), 2017-06-05 (Lundi de pentecote'17), 2017-09-07 (Jeune genevois'17), 2017-12-25 to 2018-01-05 (Noel'17).

## Resources

| Resource | Group |
| --- | --- |
| Aurelien Benjamin Dodard | DOP |
| CE draugthsman | DOP |
| Cristiana Colloca | PO |
| Fabien Yvan Vincent | HE |
| Franck Audinet | HE |
| Miriam Munoz Codoceo | HE |
| Raul Fernandez Ortega | DOP |
| CMS |  |
| DGS/SEE |  |
| Denis Raffourt |  |
| Leszek Borakiewicz |  |
| Helder Lourenco |  |
| DGS/RP |  |
| EXT |  |
| Nino Rama |  |
| 30ss |  |
| HSE/SEE |  |

## Schedule

| ID | WBS | Task | Type | Duration | Start | Finish | Predecessors | Complete | Remaining | Baseline start | Baseline finish | Baseline duration | Total slack | Free slack | Constraint | Resources | Work | Actual work | Cost | Actual cost | Building |
| --- | --- | --- | --- | --- | --- | --- | --- | --- | --- | --- | --- | --- | --- | --- | --- | --- | --- | --- | --- | --- | --- |
| 1 | 1 | **RWTC & ISR** |  | 2007d | 2015-01-05 A | 2022-11-18 |  | 40% | 1206.74d |  |  |  | 0d |  |  |  | 13966.5h | 5401.82h | 12,484,550 | 5,295,715 | 375 |
| 2 | 1.1 | **Design and procurement** |  | 769d | 2015-05-04 A | 2018-06-14 |  | 57% | 327.37d | 2015-03-23 | 2015-12-16 | 0d | 1156d |  |  |  | 3076.4h | 880.4h | 4,164,000 | 3,085,740 | 375 |
| 3 | 1.1.1 | Fire risk assessment | milestone | 16.8w | 2015-09-22 A | 2016-01-29 |  | 61% | 6.6w |  |  |  | 1743d |  | finish no earlier than 2016-01-29 | Cristiana Colloca [30%] | 201.6h | 122.4h | 34,000 | 20,740 | 375 |
| 4 | 1.1.2 | **Civil engineering and architecture** |  | 766d | 2015-05-04 A | 2018-06-11 |  | 72% | 216.65d | 2015-03-30 | 2015-06-26 | 0d | 1119d |  |  |  | 294h | 294h |  |  | 375 |
| 5 | 1.1.2.1 | **Tender procedures for Works** |  | 766d | 2015-05-04 A | 2018-06-11 |  | 72% | 216.65d | 2015-03-30 | 2015-06-26 | 0d | 1119d |  |  |  | 294h | 294h |  |  | 375 |
| 6 | 1.1.2.1.1 | **Price enquiry** |  | 766d | 2015-05-04 A | 2018-06-11 |  | 58% | 324.97d | 2015-03-30 | 2015-06-26 | 0d | 1119d |  |  |  | 180h | 180h |  |  | 375 |
| 7 | 1.1.2.1.1.1 | **Price enquiry preparation** |  | 731d | 2015-05-04 A | 2018-04-23 |  | 57% | 313.29d | 2015-03-30 | 2015-05-11 | 0d | 1099d |  |  |  | 148h | 148h |  |  | 375 |
| 8 | 1.1.2.1.1.1.1 | Supports for crane to be extended ISR4 and other metal works |  | 2w | 2016-06-20 A | 2016-07-01 A |  | 100% |  | 2015-03-30 | 2015-04-23 | 0d |  |  | start no earlier than 2016-02-22 | CE draugthsman [10%]; Aurelien Benjamin Dodard [5%]; Cristiana Colloca [40%]; Raul Fernandez Ortega [20%] | 60h | 60h |  |  | 375 |
| 9 | 1.1.2.1.1.1.2 | Various metallic doors renovation + double entrance doors for ventil |  | 2w | 2015-09-21 A | 2015-10-02 A |  | 100% |  |  |  |  |  |  |  | Cristiana Colloca [40%]; CE draugthsman [10%]; Aurelien Benjamin Dodard [5%] | 44h | 44h |  |  | 375 |
| 10 | 1.1.2.1.1.1.3 | New grids 20 t for access tunnels |  | 2w | 2015-05-04 A | 2015-05-15 A |  | 100% |  |  |  |  |  |  |  | Cristiana Colloca [40%]; Aurelien Benjamin Dodard [20%] | 36h | 36h |  |  | 375 |
| 11 | 1.1.2.1.1.1.4 | Ventilation units dismantling |  | 2w | 2015-10-19 A | 2015-10-30 A |  | 100% |  |  |  |  |  |  | start no earlier than 2015-10-19 | Cristiana Colloca [10%] | 8h | 8h |  |  | 375 |
| 12 | 1.1.2.1.1.1.5 | Stairs replacement ISR2, ISR4, ISR8 |  | 2w | 2017-11-13 | 2017-11-24 |  |  |  |  |  |  | 1195d | 0d | start no earlier than 2017-11-13 |  |  |  |  |  | 375 |
| 13 | 1.1.2.1.1.1.6 | New door ISR2 for ventil + 2 fire doors ground level |  | 2w | 2018-04-10 | 2018-04-23 |  |  |  |  |  |  | 1089d | 0d | start no earlier than 2018-04-10 |  |  |  |  |  | 375 |
| 14 | 1.1.2.1.1.1.7 | Civil eng works for HVAC |  | 2w | 2018-04-10 | 2018-04-23 |  |  |  |  |  |  | 1044d | 0d | start no earlier than 2018-04-10 |  |  |  |  |  | 375 |
| 15 | 1.1.2.1.1.2 | **Check before sending** |  | 732d | 2015-05-18 A | 2018-05-07 |  | 53% | 341.6d | 2015-04-17 | 2015-05-21 | 0d | 1104d |  |  |  | 32h | 32h |  |  | 375 |
| 16 | 1.1.2.1.1.2.1 | Supports for crane to be extended ISR4 and other metal works |  | 2w | 2016-07-04 A | 2016-07-15 A | 8 | 100% |  | 2015-04-17 | 2015-04-30 | 0d |  |  |  | Cristiana Colloca [10%] | 8h | 8h |  |  | 375 |
| 17 | 1.1.2.1.1.2.2 | Various metallic doors renovation + double entrance doors for ventil |  | 2w | 2015-10-05 A | 2015-10-16 A | 9 | 100% |  |  |  |  |  |  |  | Cristiana Colloca [10%] | 8h | 8h |  |  | 375 |
| 18 | 1.1.2.1.1.2.3 | New grids 20 t for access tunnels |  | 2w | 2015-05-18 A | 2015-06-01 A | 10 | 100% |  |  |  |  |  |  |  | Cristiana Colloca [10%] | 8h | 8h |  |  | 375 |
| 19 | 1.1.2.1.1.2.4 | Ventilation units dismantling |  | 2w | 2015-11-02 A | 2015-11-13 A | 11 | 100% |  |  |  |  |  |  |  | Cristiana Colloca [10%] | 8h | 8h |  |  | 375 |
| 20 | 1.1.2.1.1.2.5 | Stairs replacement ISR2, ISR4, ISR8 + IPT |  | 3w | 2017-11-27 | 2017-12-15 | 12 |  |  |  |  |  | 1195d | 0d |  |  |  |  |  |  |  |
| 21 | 1.1.2.1.1.2.6 | New door ISR2 for ventil + 2 fire doors ground level |  | 2w | 2018-04-24 | 2018-05-07 | 13 |  |  |  |  |  | 1089d | 0d | start no earlier than 2018-03-30 |  |  |  |  |  | 375 |
| 22 | 1.1.2.1.1.2.7 | Civil eng works for HVAC |  | 2w | 2018-04-24 | 2018-05-07 | 14 |  |  |  |  |  | 1044d | 0d | start no earlier than 2018-04-10 |  |  |  |  |  | 375 |
| 23 | 1.1.2.1.1.3 | **Time for bidding** |  | 747d | 2015-06-02 A | 2018-06-11 |  | 59% | 302.84d | 2015-05-04 | 2015-06-26 | 0d | 1119d |  |  |  |  |  |  |  | 375 |
| 24 | 1.1.2.1.1.3.1 | Supports for crane to be extended ISR4 and other metal works |  | 7w | 2016-07-18 A | 2016-09-02 A | 16 | 100% |  | 2015-05-04 | 2015-06-09 | 0d |  |  |  |  |  |  |  |  | 375 |
| 25 | 1.1.2.1.1.3.2 | Various metallic doors renovation + double entrance doors for ventil |  | 5w | 2015-10-19 A | 2015-11-20 A | 17 | 100% |  |  |  |  |  |  | start no earlier than 2015-04-27 |  |  |  |  |  | 375 |
| 26 | 1.1.2.1.1.3.3 | New grids 20 t for access tunnels |  | 5w | 2015-06-02 A | 2015-07-15 A | 18FS+2w | 100% |  |  |  |  |  |  |  |  |  |  |  |  | 375 |
| 27 | 1.1.2.1.1.3.4 | Ventilation units dismantling |  | 5w | 2016-01-12 A | 2016-02-15 A |  | 100% |  |  |  |  |  |  | start no earlier than 2016-01-12 |  |  |  |  |  | 375 |
| 28 | 1.1.2.1.1.3.5 | Stairs replacement ISR2, ISR4, ISR8 |  | 5w | 2018-01-22 | 2018-02-23 | 20FS+3w |  |  |  |  |  | 1195d | 0d |  |  |  |  |  |  | 375 |
| 29 | 1.1.2.1.1.3.6 | New door ISR2 for ventil + 2 fire doors ground level |  | 5w | 2018-05-08 | 2018-06-11 | 21 |  |  |  |  |  | 1089d | 0d | start no earlier than 2018-03-30 |  |  |  |  |  | 375 |
| 30 | 1.1.2.1.1.3.7 | Civil eng works for HVAC |  | 5w | 2018-05-08 | 2018-06-11 | 22 |  |  |  |  |  | 1044d | 0d | start no earlier than 2018-04-10 |  |  |  |  |  | 375 |
| 31 | 1.1.2.1.2 | Market Survey undergroung galeries waterproofing |  | 85d | 2016-04-18 A | 2016-08-17 A |  | 100% |  | 2015-04-20 | 2015-08-17 | 0d |  |  |  |  | 42h | 42h |  |  | 375 |
| 35 | 1.1.2.1.3 | Invitation to tender undergroung galeries waterprofing |  | 85d | 2016-09-26 A | 2017-02-03 A |  | 100% |  | 2015-06-09 | 2015-10-13 | 0d |  |  |  |  | 72h | 72h |  |  | 375 |

| ID | WBS | Task | Type | Duration | Start | Finish | Predecessors | Complete | Remaining | Baseline start | Baseline finish | Baseline duration | Total slack | Free slack | Constraint | Resources | Work | Actual work | Cost | Actual cost | Building |
| --- | --- | --- | --- | --- | --- | --- | --- | --- | --- | --- | --- | --- | --- | --- | --- | --- | --- | --- | --- | --- | --- |
| 41 | 1.1.3 | **Asbestos** |  | 26d | 2015-08-28 A | 2015-10-05 A |  | 100% |  |  |  |  |  |  |  |  | 8h | 8h |  |  | 375 |
| 42 | 1.1.3.1 | Asbestos diagnostic reports (all) available | milestone | 1d | 2015-08-28 A | 2015-08-28 A |  | 100% |  |  |  |  |  |  | start no earlier than 2015-08-28 | DGS/SEE | 8h | 8h |  |  | 375 |
| 43 | 1.1.3.2 | Work definition |  | 4w | 2015-09-07 A | 2015-10-05 A | 42FS+1w | 100% |  |  |  |  |  |  |  |  |  |  |  |  | 375 |
| 44 | 1.1.4 | **HVAC** |  | 656d | 2015-10-13 A | 2018-06-14 |  | 34% | 434.65d | 2015-03-23 | 2015-12-16 | 0d | 1156d |  |  |  | 2124.8h | 232h | 2,000,000 | 2,000,000 | 375 |
| 45 | 1.1.4.1 | HVAC Construction design for MS |  | 6w | 2015-10-13 A | 2015-11-23 A | 3SS+3w | 100% |  | 2015-03-23 | 2015-05-11 | 0d |  |  |  | Franck Audinet [40%] | 96h | 96h | 2,000,000 | 2,000,000 | 375 |
| 46 | 1.1.4.2 | Concept finalized to be sumbmitted to Autorities |  | 5w | 2017-04-25 | 2017-05-31 |  |  |  | 2015-03-23 | 2015-05-11 | 0d | 1215d | 0d | finish no earlier than 2017-05-31 | Franck Audinet [40%] | 80h |  |  |  | 375 |
| 47 | 1.1.4.3 | Concept review by Autorities |  | 14w | 2017-06-01 | 2017-09-08 | 46 |  |  |  |  |  | 1215d | 17d |  |  |  |  |  |  | 375 |
| 48 | 1.1.4.4 | Reviewed concept after Autorities reply |  | 1w | 2017-10-04 | 2017-10-10 | 47 |  |  |  |  |  | 1198d | 0d | start no earlier than 2017-10-04 |  |  |  |  |  | 375 |
| 49 | 1.1.4.5 | **Tender procedures for Works** |  | 534d | 2015-11-24 A | 2018-02-06 |  | 43% | 303.08d | 2015-04-20 | 2015-10-13 | 0d | 1248d |  |  | Franck Audinet [40%] | 1948.8h | 136h |  |  | 375 |
| 50 | 1.1.4.5.1 | Market Survey > 750 KCHF |  | 80d | 2015-11-24 A | 2016-03-30 A |  | 100% |  | 2015-04-20 | 2015-08-17 | 0d |  |  |  |  | 72h | 72h |  |  | 375 |
| 54 | 1.1.4.5.2 | Invitation to tender > 750 KCHF |  | 167d | 2017-06-01 | 2018-02-06 |  |  |  | 2015-06-09 | 2015-10-13 | 0d | 1248d |  |  |  | 168h |  |  |  | 375 |
| 59 | 1.1.4.6 | FC adjudication procedures and contract preparation |  | 2w | 2018-02-07 | 2018-02-20 |  |  |  | 2015-10-14 | 2015-10-27 | 0d | 1198d | 0d |  |  |  |  |  |  | 375 |
| 60 | 1.1.4.7 | **Proposition to FC** |  | 42d | 2018-04-17 | 2018-06-14 |  |  |  | 2015-10-16 | 2015-12-16 | 0d | 814.5d |  |  |  |  |  |  |  | 375 |
| 61 | 1.1.4.7.1 | Proposition to FC (date calculee plus 8 w) | milestone | 0w | 2018-04-17 | 2018-04-17 | 59FS+8w |  |  | 2015-10-16 | 2015-10-16 | 0d | 1198d |  | start no earlier than 2017-03-27 |  |  |  |  |  | 375 |
| 62 | 1.1.4.7.2 | FC | milestone | 1d | 2018-06-14 | 2018-06-14 |  |  |  | 2015-12-16 | 2015-12-16 | 0d | 773.5d | 0d | start no earlier than 2018-06-14 |  |  |  |  |  | 375 |
| 63 | 1.1.5 | **Electricity** |  | 70d | 2016-04-29 A | 2016-08-09 |  | 50% | 35d | 2015-03-23 | 2015-12-16 | 0d | 1611d |  |  | Miriam Munoz Codoceo [40%] | 448h | 224h | 2,130,000 | 1,065,000 | 375 |
| 64 | 1.1.5.1 | Pre studies, calculations, budget etc. |  | 14w | 2016-04-29 A | 2016-08-09 |  | 50% | 7w | 2015-03-23 | 2015-05-11 | 0d | 1611d |  | start no earlier than 2016-04-29 | Miriam Munoz Codoceo [40%] | 224h | 112h | 2,130,000 | 1,065,000 | 375 |
| 66 | 1.2 | **Works** |  | 2007d | 2015-01-05 A | 2022-11-18 |  | 36% | 1287.92d | 2015-03-11 | 2016-10-24 | 0d | 0d |  |  |  | 10890.1h | 4521.42h | 8,320,550 | 2,209,975 |  |
| 67 | 1.2.1 | **Bldg 184 - ISR4 - RWTC** |  | 1194.5d | 2015-02-27 A | 2019-12-03 |  | 65% | 423.08d | 2015-03-11 | 2016-10-24 | 0d | 773.5d |  |  | Cristiana Colloca [20%] | 5870h | 3284.02h | 1,533,950 | 723,575 |  |
| 68 | 1.2.1.1 | **HSE/RP machines** |  | 643d | 2015-04-27 A | 2017-11-30 |  | 98% | 14.78d |  |  |  | 1286d |  |  |  | 566h | 550h |  |  |  |
| 69 | 1.2.1.1.1 | Truck3 unloading |  | 1d | 2015-04-27 A | 2015-04-27 A |  | 100% |  |  |  |  |  |  | start no earlier than 2015-04-27 | EXT; Helder Lourenco [20%] | 9.6h | 9.6h |  |  |  |
| 70 | 1.2.1.1.2 | Truck2 unloading |  | 1d | 2015-04-30 A | 2015-04-30 A |  | 100% |  |  |  |  |  |  | start no earlier than 2015-04-30 | EXT; Helder Lourenco [20%] | 9.6h | 9.6h |  |  |  |
| 71 | 1.2.1.1.3 | Truck1 unloading |  | 1d | 2015-04-30 A | 2015-04-30 A | 70FF | 100% |  |  |  |  |  |  | start no earlier than 2015-04-30 | EXT; Helder Lourenco [20%] | 9.6h | 9.6h |  |  |  |
| 72 | 1.2.1.1.4 | Truck4 unloading |  | 1d | 2015-05-06 A | 2015-05-06 A |  | 100% |  |  |  |  |  |  | start no earlier than 2015-05-06 | EXT; Helder Lourenco [20%] | 9.6h | 9.6h |  |  |  |
| 73 | 1.2.1.1.5 | Truck6 unloading |  | 1d | 2015-05-07 A | 2015-05-07 A |  | 100% |  |  |  |  |  |  | start no earlier than 2015-05-07 | EXT; Helder Lourenco [20%] | 9.6h | 9.6h |  |  |  |
| 74 | 1.2.1.1.6 | Truck5 unloading |  | 1d | 2015-05-07 A | 2015-05-07 A | 73FF | 100% |  |  |  |  |  |  | start no earlier than 2015-05-07 | EXT; Helder Lourenco [20%] | 9.6h | 9.6h |  |  |  |
| 75 | 1.2.1.1.7 | Installation of the oil pan and feet |  | 6d | 2015-05-11 A | 2015-05-18 A |  | 100% |  |  |  |  |  |  | start no earlier than 2015-05-11 | EXT | 48h | 48h |  |  |  |
| 76 | 1.2.1.1.8 | Installation of the tete sur coffre |  | 1d | 2015-05-18 A | 2015-05-18 A |  | 100% |  |  |  |  |  |  | start no earlier than 2015-05-18 | EXT | 8h | 8h |  |  |  |
| 77 | 1.2.1.1.9 | Installation of the access platform |  | 2d | 2015-05-19 A | 2015-05-20 A |  | 100% |  |  |  |  |  |  | start no earlier than 2015-05-19 | EXT | 16h | 16h |  |  |  |
| 78 | 1.2.1.1.10 | Installation of the skip |  | 3d | 2015-05-21 A | 2015-05-26 A |  | 100% |  |  |  |  |  |  | start no earlier than 2015-05-21 | EXT | 24h | 24h |  |  |  |
| 79 | 1.2.1.1.11 | Installation of the dust hood |  | 5d | 2015-05-22 A | 2015-05-29 A |  | 100% |  |  |  |  |  |  | start no earlier than 2015-05-22 | EXT | 40h | 40h |  |  |  |
| 80 | 1.2.1.1.12 | Press-shear machine finishing |  | 5d | 2015-06-08 A | 2015-06-12 A |  | 100% |  | 2015-05-26 | 2015-05-26 | 0d |  |  | start no earlier than 2015-06-08 | EXT | 40h | 40h |  |  |  |
| 81 | 1.2.1.1.13 | Cabin installed and commissioned |  | 1d | 2015-06-12 A | 2015-06-12 A | 80FF | 100% |  | 2015-05-26 | 2015-05-26 | 0d |  |  | start no earlier than 2015-05-11 | EXT | 8h | 8h |  |  |  |
| 82 | 1.2.1.1.14 | Controlled access barriers installed |  | 1d | 2015-06-12 A | 2015-06-12 A | 81FF | 100% |  | 2015-06-10 | 2015-06-10 | 0d |  |  |  | EXT | 8h | 8h |  |  |  |
| 83 | 1.2.1.1.15 | Tests & inspections (NO ACCESS TO THE WHOLE AREA) |  | 1w | 2015-06-15 A | 2015-06-19 A |  | 100% |  |  |  |  |  |  | start no earlier than 2015-06-15 | EXT | 40h | 40h |  |  |  |
| 84 | 1.2.1.1.16 | Finishing work on the machine (no coactivity around the machine) |  | 1w | 2015-07-06 A | 2015-07-10 A |  | 100% |  |  |  |  |  |  | start no earlier than 2015-07-06 | EXT | 40h | 40h |  |  |  |
| 85 | 1.2.1.1.17 | Filter unit delivery |  | 1d | 2015-06-26 A | 2015-06-26 A |  | 100% |  |  |  |  |  |  | start no earlier than 2015-06-26 | EXT; Helder Lourenco [20%] | 9.6h | 9.6h |  |  |  |
| 86 | 1.2.1.1.18 | Filter unit installation |  | 1w | 2015-06-29 A | 2015-07-03 A |  | 100% |  |  |  |  |  |  | start no earlier than 2015-06-29 | EXT | 40h | 40h |  |  |  |
| 87 | 1.2.1.1.19 | Installation Fire Protection of filter unit |  | 1w | 2015-07-06 A | 2015-07-10 A |  | 100% |  |  |  |  |  |  | start no earlier than 2015-07-06 | EXT | 40h | 40h |  |  |  |
| 88 | 1.2.1.1.20 | Filter unit installed and commissioned |  | 2d | 2015-07-13 A | 2015-07-14 |  | 75% | 0.5d | 2015-06-30 | 2015-06-30 | 0d | 1.5d | 0d | start no earlier than 2015-07-13 | EXT | 16h | 12h |  |  |  |
| 89 | 1.2.1.1.21 | General commissioning and inspections |  | 2d | 2015-07-16 A | 2015-07-17 | 88FS+1d | 75% | 0.5d | 2015-06-30 | 2015-06-30 | 0d | 1872d |  | start no earlier than 2015-06-23 | EXT | 16h | 12h |  |  |  |
| 90 | 1.2.1.1.22 | General test (NO ACCESS) |  | 1d | 2015-07-16 A | 2015-07-16 A |  | 100% |  |  |  |  |  |  | start no earlier than 2015-07-16 | EXT | 8h | 8h |  |  |  |
| 91 | 1.2.1.1.23 | TRAINING (NO ACCESS) |  | 1w | 2015-07-20 A | 2015-07-24 A | 89 | 100% |  |  |  |  |  |  |  | DGS/RP | 40h | 40h |  |  |  |
| 92 | 1.2.1.1.24 | Cutting cell installed |  | 1d | 2017-11-30 | 2017-11-30 |  |  |  | 2016-10-24 | 2016-10-24 | 0d | 1284d | 0d | start no earlier than 2017-11-30 | EXT | 8h |  |  |  |  |
| 93 | 1.2.1.1.25 | CMS zone removal |  | 5w | 2015-05-04 A | 2015-06-09 A |  | 100% |  |  |  |  |  |  | start no earlier than 2015-05-04 | Aurelien Benjamin Dodard [40%] | 58.8h | 58.8h |  |  |  |

| ID | WBS | Task | Type | Duration | Start | Finish | Predecessors | Complete | Remaining | Baseline start | Baseline finish | Baseline duration | Total slack | Free slack | Constraint | Resources | Work | Actual work | Cost | Actual cost |
| --- | --- | --- | --- | --- | --- | --- | --- | --- | --- | --- | --- | --- | --- | --- | --- | --- | --- | --- | --- | --- |
| 94 | 1.2.1.2 | **Civil engineering & bldg works** |  | 984d | 2015-02-27 A | 2019-02-12 |  | 69% | 300.23d | 2015-03-25 | 2016-10-21 | 0d | 984d |  |  | Cristiana Colloca [20%] | 3097.6h | 1185.6h | 578,750 | 273,325 |
| 95 | 1.2.1.2.1 | Worksite fencing |  | 2d | 2015-04-24 A | 2015-04-27 A | 69FF | 100% |  |  |  |  |  |  |  | Aurelien Benjamin Dodard [40%] | 8h | 8h | 500 | 500 |
| 96 | 1.2.1.2.2 | Plateform reinforcement behind machine (2t/m2) |  | 10d | 2015-06-22 A | 2015-07-03 A |  | 100% |  | 2015-04-13 | 2015-04-24 | 0d |  |  | start no earlier than 2015-06-22 | Aurelien Benjamin Dodard [50%]; Raul Fernandez Ortega [20%]; CE draugthsman [20%] | 72h | 72h | 7,000 | 7,000 |
| 97 | 1.2.1.2.3 | Press-shear machine foundation |  | 5w | 2015-02-27 A | 2015-04-02 A |  | 100% |  | 2015-03-25 | 2015-05-05 | 0d |  |  | start no earlier than 2015-02-27 | Aurelien Benjamin Dodard [50%]; Raul Fernandez Ortega [50%] | 140h | 140h | 35,000 | 35,000 |
| 98 | 1.2.1.2.4 | Foundation wall painting |  | 3d | 2015-04-22 A | 2015-04-24 A |  | 100% |  |  |  |  |  |  | start no earlier than 2015-04-22 | Aurelien Benjamin Dodard [40%] | 12h | 12h | 350 | 350 |
| 99 | 1.2.1.2.5 | Vertical metallic plates in safety area |  | 1w | 2015-03-27 A | 2015-04-02 A | 97FF | 100% |  | 2015-04-28 | 2015-05-05 | 0d |  |  |  | Aurelien Benjamin Dodard [40%] | 20h | 20h | 5,000 | 5,000 |
| 100 | 1.2.1.2.6 | New holes in foundation for elec cabinet feeding |  | 2d | 2015-04-27 A | 2015-04-28 A | 157SF+7d | 100% |  |  |  |  |  |  |  | Aurelien Benjamin Dodard [40%] | 8h | 8h | 750 | 750 |
| 101 | 1.2.1.2.7 | Safety area at ground level painting |  | 1w | 2016-01-18 A | 2016-01-22 A |  | 100% |  | 2015-05-27 | 2015-05-29 | 0d |  |  | start no earlier than 2016-01-18 | Aurelien Benjamin Dodard [50%]; CE draugthsman [10%] | 24h | 24h | 50,000 | 50,000 |
| 102 | 1.2.1.2.8 | Cantilever modification for control cabin |  | 1w | 2015-06-01 A | 2015-06-05 A |  | 100% |  | 2015-05-04 | 2015-05-08 | 0d |  |  | start no earlier than 2015-06-01 | Aurelien Benjamin Dodard [50%]; Raul Fernandez Ortega [50%]; CE draugthsman [5%] | 42h | 42h | 2,500 | 2,500 |
| 103 | 1.2.1.2.9 | Barriers modif for cabin |  | 1d | 2015-06-23 A | 2015-06-23 A |  | 100% |  | 2015-05-04 | 2015-05-04 | 0d |  |  | start no earlier than 2015-06-23 | Aurelien Benjamin Dodard [50%]; CE draugthsman [20%] | 5.6h | 5.6h | 750 | 750 |
| 104 | 1.2.1.2.10 | Floor: repairs, drainages sealing |  | 2w | 2015-07-02 A | 2015-07-15 A |  | 100% |  | 2015-07-20 | 2015-07-24 | 0d |  |  | finish no earlier than 2015-07-15 | Aurelien Benjamin Dodard [40%] | 12.8h | 12.8h | 1,000 | 1,000 |
| 105 | 1.2.1.2.11 | Floor: resin and zoning |  | 2w | 2015-08-24 A | 2015-09-04 A | 106FF | 100% |  | 2015-07-20 | 2015-07-24 | 0d |  |  | finish no earlier than 2015-07-15 | Aurelien Benjamin Dodard [40%] | 12.8h | 12.8h | 10,000 | 10,000 |
| 106 | 1.2.1.2.12 | Cavern painting (on shift 8/8) |  | 6w | 2015-07-27 A | 2015-09-04 A | 91 | 100% |  | 2015-05-27 | 2015-06-23 | 0d |  |  |  | Aurelien Benjamin Dodard [40%] | 96h | 96h | 16,000 | 16,000 |
| 107 | 1.2.1.2.13 | First cleaning of floor |  | 2d | 2015-07-16 A | 2015-07-17 A |  | 100% |  |  |  |  |  |  | start no earlier than 2015-07-16 | Aurelien Benjamin Dodard [40%] | 6.4h | 6.4h | 350 | 350 |
| 108 | 1.2.1.2.14 | Final floor cleaning |  | 2d | 2015-09-07 | 2015-09-08 | 106 |  |  | 2015-06-24 | 2015-06-25 | 0d | 1835d |  |  | Aurelien Benjamin Dodard [40%] | 6.4h |  | 350 |  |
| 109 | 1.2.1.2.15 | Old gas pipe dismounting |  | 1d | 2015-04-24 A | 2015-04-24 A |  | 100% |  |  |  |  |  |  | start no earlier than 2015-04-24 | Aurelien Benjamin Dodard [40%] | 4h | 4h | 100 | 100 |
| 110 | 1.2.1.2.16 | 5 mt grill to complete access controle barrier |  | 3d | 2015-06-10 A | 2015-06-12 A |  | 100% |  | 2015-06-03 | 2015-06-10 | 0d |  |  | start no earlier than 2015-06-10 | Aurelien Benjamin Dodard [40%] | 9.6h | 9.6h | 2,000 | 2,000 |
| 111 | 1.2.1.2.17 | Door for gate on plateform behind machine |  | 2d | 2015-06-04 A | 2015-06-05 |  | 75% | 0.5d | 2015-04-27 | 2015-05-04 | 0d | 1902d |  | start no earlier than 2015-06-04 | Aurelien Benjamin Dodard [50%]; CE draugthsman [20%] | 11.2h | 8.4h | 4,500 | 3,375 |
| 112 | 1.2.1.2.18 | Door for gate to access safety zone ground level (between filter unit and machine) |  | 2d | 2015-06-04 A | 2015-06-05 A | 111SS | 100% |  |  |  |  |  |  |  | Aurelien Benjamin Dodard [50%]; CE draugthsman [20%] | 11.2h | 11.2h | 3,500 | 3,500 |
| 113 | 1.2.1.2.19 | Gate to access safety zone ground level (near filter unit) + grids completion |  | 3d | 2015-06-24 A | 2015-06-26 A | 103 | 100% |  | 2015-05-05 | 2015-05-11 | 0d |  |  |  | Aurelien Benjamin Dodard [50%]; CE draugthsman [20%] | 16.8h | 16.8h | 4,500 | 4,500 |
| 114 | 1.2.1.2.20 | Supports for ducts between filter unit and machine + supports for ducts for filter unit | manual | 2d | 2015-06-12 A | 2015-06-22 A |  | 100% |  |  |  |  |  |  | start no earlier than 2015-06-12 | Aurelien Benjamin Dodard [50%]; Raul Fernandez Ortega [50%]; CE draugthsman [20%] | 19.2h | 19.2h | 2,500 | 2,500 |
| 115 | 1.2.1.2.21 | Wooden door and frame dismounting (chimney) to install the provisional plateform | manual | 1d | 2015-05-26 A | 2015-05-26 A |  | 100% |  |  |  |  |  |  |  | Aurelien Benjamin Dodard [40%] | 3.2h | 3.2h | 1,500 | 1,500 |
| 116 | 1.2.1.2.22 | Final/permanent plateforme inside the chimney |  | 1d | 2015-07-31 A | 2015-07-31 A |  | 100% |  |  |  |  |  |  | start no earlier than 2015-06-22 | Aurelien Benjamin Dodard [50%]; Raul Fernandez Ortega [50%]; CE draugthsman [20%] | 9.6h | 9.6h | 1,500 | 1,500 |
| 117 | 1.2.1.2.23 | Sealing around the chimney (b. 598) |  | 1w | 2015-07-28 A | 2015-08-03 A | 116SF+2d | 100% |  |  |  |  |  |  | start no earlier than 2015-07-06 | Aurelien Benjamin Dodard [40%] | 16h | 16h | 2,000 | 2,000 |
| 118 | 1.2.1.2.24 | Door blocking room 184/S-A39 | manual | 1d | 2015-07-03 A | 2015-07-03 A | 117SF | 100% |  |  |  |  |  |  |  | Aurelien Benjamin Dodard [40%] | 3.2h | 3.2h | 250 | 250 |
| 119 | 1.2.1.2.25 | Staircase moving in bldg 184 |  | 3d | 2015-04-08 A | 2015-04-10 A |  | 100% |  | 2015-05-05 | 2015-05-11 | 0d |  |  | start no earlier than 2015-04-08 | Aurelien Benjamin Dodard [50%]; Raul Fernandez Ortega [20%]; CE draugthsman [20%] | 19.2h | 19.2h | 750 | 750 |
| 120 | 1.2.1.2.26 | Acoustic insulation |  | 4w | 2017-12-04 | 2018-01-12 | 149 |  |  | 2016-09-26 | 2016-10-21 | 0d | 1265d |  | start no earlier than 2016-10-31 | Aurelien Benjamin Dodard [40%] | 64h |  |  |  |
| 121 | 1.2.1.2.27 | Drainage refurbishment for extinguishing water system |  | 2w | 2015-11-09 | 2015-11-20 | 160 |  |  | 2015-07-27 | 2015-08-07 | 0d | 1783d |  |  | Aurelien Benjamin Dodard [40%] | 32h |  | 2,500 |  |
| 122 | 1.2.1.2.28 | Windows modification for natural smoke extrac.(+ glass??) |  | 1w | 2016-05-30 | 2016-06-03 |  |  |  | 2015-05-12 | 2015-05-18 | 0d | 1658d |  | start no earlier than 2016-05-30 | Aurelien Benjamin Dodard [40%] | 16h |  | 10,000 |  |
| 123 | 1.2.1.2.29 | Barrack bldg 172 deconnection |  | 1d | 2015-05-14 A | 2015-05-15 A | 222SF | 100% |  |  |  |  |  |  |  | Aurelien Benjamin Dodard [40%] | 8h | 8h | 500 | 500 |
| 124 | 1.2.1.2.30 | Foundations works for external barracks (demolishing, cleaning, reiforcement, barriers modif.) |  | 1w | 2015-05-04 A | 2015-05-08 A | 222SF-1w | 100% |  |  |  |  |  |  |  | Aurelien Benjamin Dodard [20%]; Raul Fernandez Ortega [20%]; CE draugthsman [50%] | 36h | 36h | 500 | 500 |
| 125 | 1.2.1.2.31 | EU connections for external barracks |  | 2d | 2015-07-09 A | 2015-07-10 A |  | 100% |  |  |  |  |  |  | start no earlier than 2015-07-09 | Aurelien Benjamin Dodard [40%] | 6.4h | 6.4h | 500 | 500 |
| 126 | 1.2.1.2.32 | External barracks modification of barriers |  | 2d | 2015-08-10 A | 2015-08-11 |  | 75% | 0.5d |  |  |  | 1855d |  |  | Aurelien Benjamin Dodard [40%] | 6.4h | 4.8h | 500 | 375 |
| 127 | 1.2.1.2.33 | Entrance painting (LIMITED ACCESS FOR 2D) |  | 2w | 2015-09-07 A | 2015-09-21 A | 106 | 100% |  |  |  |  |  |  |  | Aurelien Benjamin Dodard [40%] | 32h | 32h | 3,500 | 3,500 |
| 128 | 1.2.1.2.34 | Ventil unit protection (between new ventil units intern&ext.) |  | 1w | 2015-10-19 A | 2015-10-23 A |  | 100% |  |  |  |  |  |  | start no earlier than 2015-10-12 | Aurelien Benjamin Dodard [40%] | 16h | 16h | 4,600 | 4,600 |
| 129 | 1.2.1.2.35 | Wooden wall dismantling behind blocs CMS (ISR4-5) |  | 2d | 2015-06-11 A | 2015-06-12 A |  | 100% |  |  |  |  |  |  | start no earlier than 2015-06-11 | Aurelien Benjamin Dodard [40%] | 6.4h | 6.4h | 500 | 500 |
| 130 | 1.2.1.2.36 | Floor/trappes repairs mezzanine (+ISR5L) |  | 10d | 2016-02-01 A | 2016-02-12 A |  | 100% |  |  |  |  |  |  | start no earlier than 2016-02-01 | Aurelien Benjamin Dodard [40%] | 32h | 32h | 13,000 | 13,000 |
| 131 | 1.2.1.2.37 | Floor preparation for inclineurs |  | 10d | 2016-05-16 A | 2016-05-30 A |  | 100% |  |  |  |  |  |  | start no earlier than 2016-02-01 | Aurelien Benjamin Dodard [40%] | 32h | 32h | 1,400 | 1,400 |
| 132 | 1.2.1.2.38 | Various metallic doors renovation |  | 1w | 2017-03-27 A | 2017-03-31 |  | 90% | 0.1w | 2015-05-12 | 2015-06-10 | 0d | 1454d |  | start no earlier than 2017-03-27 | Aurelien Benjamin Dodard [20%] | 8h | 7.2h | 7,000 | 6,300 |
| 133 | 1.2.1.2.39 | Concrete lintell ISR4 |  | 2w | 2017-07-10 A | 2017-07-21 A |  | 100% |  |  |  |  |  |  | start no earlier than 2017-07-10 |  |  |  | 1,000 | 1,000 |
| 134 | 1.2.1.2.40 | New door for ventil (replacement) |  | 1w | 2017-11-13 | 2017-11-17 |  |  |  |  |  |  | 1295d |  | start no earlier than 2017-11-13 | Aurelien Benjamin Dodard [35%] | 14h |  | 36,000 |  |
| 135 | 1.2.1.2.41 | Concrete demolishing for one pillar of the crane extension |  | 1w | 2016-02-22 A | 2016-02-26 A |  | 100% |  |  |  |  |  |  | start no earlier than 2016-02-22 | Aurelien Benjamin Dodard [40%] | 16h | 16h | 2,800 | 2,800 |
| 136 | 1.2.1.2.42 | Preparation and finishing works for crane rails and supports extension |  | 3w | 2016-10-18 A | 2016-11-07 A |  | 100% |  |  |  |  |  |  |  |  |  |  | 6,500 | 6,500 |
| 137 | 1.2.1.2.43 | Crane rails and supports extension ISR5 to ISR 4 |  | 18.4w | 2017-03-13 A | 2017-07-25 A |  | 100% |  | 2016-01-25 | 2016-02-12 | 0d |  |  | start no earlier than 2017-03-13 | Aurelien Benjamin Dodard [20%]; Raul Fernandez Ortega [20%]; CE draugthsman [50%] | 180h | 180h | 35,000 | 35,000 |
| 138 | 1.2.1.2.44 | Rails dismounting from the slab (to be confirmed) |  | 3d | 2016-09-21 A | 2016-09-23 A | 139FF | 100% |  | 2016-09-20 | 2016-09-26 | 0d |  |  |  | Aurelien Benjamin Dodard [40%] | 9.6h | 9.6h |  |  |
| 139 | 1.2.1.2.45 | Concrete demolishing for cutting cell (to be determined) | manual | 2w | 2017-11-13 | 2017-11-24 |  |  |  | 2016-09-09 | 2016-09-26 | 0d |  |  |  | Aurelien Benjamin Dodard [20%]; Raul Fernandez Ortega [10%] | 24h |  | 40,000 |  |
| 140 | 1.2.1.2.46 | Grids and gutters repair (including drying) |  | 1w | 2015-09-17 A | 2015-09-23 A |  | 100% |  |  |  |  |  |  | start no earlier than 2015-09-17 | Aurelien Benjamin Dodard [40%] | 16h | 16h | 9,000 | 9,000 |
| 141 | 1.2.1.2.47 | Traction tests on ducts supports (ceiling) |  | 1d | 2015-11-09 A | 2015-11-09 A | 195SS | 100% |  |  |  |  |  |  |  | Aurelien Benjamin Dodard [40%] | 3.2h | 3.2h | 500 | 500 |
| 142 | 1.2.1.2.48 | Hole to drill for cavern smoke extract (from 4 ducts) |  | 4w | 2019-01-01 | 2019-01-29 | 143SF |  |  | 2016-09-26 | 2016-10-21 | 0d | 994d |  | start no earlier than 2016-01-11 | Aurelien Benjamin Dodard [20%]; Raul Fernandez Ortega [20%]; CE draugthsman [50%] | 144h |  | 50,000 |  |
| 143 | 1.2.1.2.49 | Slab for smoke extractors |  | 2w | 2019-01-29 | 2019-02-12 | 200SF |  |  |  |  |  | 984d | 0d |  | Aurelien Benjamin Dodard [20%]; Raul Fernandez Ortega [20%]; CE draugthsman [50%] | 72h |  | 7,000 |  |
| 144 | 1.2.1.2.50 | Transformer pit preparation bldg 284 |  | 1w | 2016-05-02 A | 2016-05-10 A |  | 100% |  |  |  |  |  |  | start no earlier than 2016-05-02 |  |  |  | 5,600 | 5,600 |
| 145 | 1.2.1.2.51 | Preparation works in bldg 284 for electrical room |  | 3w | 2016-02-22 A | 2016-06-03 A |  | 100% |  |  |  |  |  |  | start no earlier than 2016-02-22 |  |  |  | 12,700 | 12,700 |
| 146 | 1.2.1.2.52 | Door modification for EL and IT room b. 184 |  | 1w | 2016-11-28 A | 2016-12-02 |  | 25% | 0.75w |  |  |  | 1529d |  | start no earlier than 2016-11-28 |  |  |  | 7,500 | 1,875 |
| 147 | 1.2.1.2.53 | Stairs modification copex |  | 1w | 2018-04-16 | 2018-04-20 | 148 |  |  |  |  |  | 1195d |  | start no earlier than 2017-04-24 |  |  |  | 15,000 |  |
| 148 | 1.2.1.2.54 | Stairs modification right |  | 1w | 2018-04-09 | 2018-04-13 | 250 |  |  |  |  |  | 1195d | 0d | start no earlier than 2017-03-27 |  |  |  | 15,000 |  |
| 149 | 1.2.1.2.55 | Fire wall and cabin structure modification |  | 5w | 2017-10-30 | 2017-12-01 |  |  |  |  |  |  | 1265d | 0d | start no earlier than 2017-10-30 |  |  |  | 70,000 |  |
| 150 | 1.2.1.2.56 | 2 fire doors separation wall |  | 1w | 2017-12-04 | 2017-12-08 | 149 |  |  |  |  |  | 1280d |  |  |  |  |  | 2,000 |  |
| 151 | 1.2.1.2.57 | Trench for EL feeding between 284 and 184 |  | 1w | 2017-02-06 A | 2017-02-10 A |  | 100% |  |  |  |  |  |  | start no earlier than 2017-02-06 |  |  |  | 6,000 | 6,000 |
| 152 | 1.2.1.2.58 | New barack and connections |  | 2w | 2017-10-30 | 2017-11-10 |  |  |  |  |  |  | 1300d |  | start no earlier than 2017-10-30 |  |  |  | 30,000 |  |
| 153 | 1.2.1.2.59 | Bldg 184 fence electrical cabinet |  | 1w | 2017-08-28 A | 2017-09-01 A |  | 100% |  |  |  |  |  |  | start no earlier than 2017-07-31 |  |  |  | 10,000 | 10,000 |
| 154 | 1.2.1.2.60 | Civil eng works for HVAC |  | 3w | 2018-08-07 | 2018-08-27 | 252 |  |  |  |  |  | 1044d | 0d |  |  |  |  | 20,000 |  |

| ID | WBS | Task | Type | Duration | Start | Finish | Predecessors | Complete | Remaining | Baseline start | Baseline finish | Baseline duration | Total slack | Free slack | Constraint | Resources | Work | Actual work | Cost | Actual cost | Contractor |
| --- | --- | --- | --- | --- | --- | --- | --- | --- | --- | --- | --- | --- | --- | --- | --- | --- | --- | --- | --- | --- | --- |
| 155 | 1.2.1.3 | **Elec** |  | 672d | 2015-03-23 A | 2017-12-08 |  | 56% | 297.89d | 2015-03-11 | 2016-10-24 | 0d | 1280d |  |  |  | 445.6h | 344h | 433,900 | 249,450 |  |
| 156 | 1.2.1.3.1 | Cables and cables tray dismounting press-shear machine zone |  | 1w | 2015-03-23 A | 2015-03-27 A | 80FF-9w | 100% |  | 2015-03-11 | 2015-03-17 | 0d |  |  |  | Fabien Yvan Vincent [50%]; Aurelien Benjamin Dodard [20%] | 16h | 16h | 5,000 | 5,000 |  |
| 157 | 1.2.1.3.2 | New cables and cabinet for machine, filter unit, access control |  | 2w | 2015-04-20 A | 2015-05-04 |  | 99% | 0w | 2015-03-18 | 2015-03-31 | 0d | 1924d |  | start no earlier than 2015-04-20 | Fabien Yvan Vincent [50%]; Aurelien Benjamin Dodard [20%]; CE draugthsman [20%] | 32h | 32h | 20,000 | 19,800 |  |
| 158 | 1.2.1.3.3 | Cut and final connection (after cabinet install.) |  | 2d | 2015-06-12 A | 2015-06-15 A |  | 100% |  |  |  |  |  |  | start no earlier than 2015-06-12 | Fabien Yvan Vincent [50%]; Aurelien Benjamin Dodard [20%] | 11.2h | 11.2h | 14,000 | 14,000 |  |
| 159 | 1.2.1.3.4 | Cabling and sockets dismantling CMS zone |  | 4w | 2015-04-15 A | 2015-05-13 |  | 95% | 0.2w |  |  |  | 1917d |  | finish no earlier than 2015-05-13 | Fabien Yvan Vincent [50%]; Aurelien Benjamin Dodard [20%] | 50.4h | 44.8h | 10,000 | 9,500 |  |
| 160 | 1.2.1.3.5 | Lighting & emerg. Lighting (including dismounting old system) (on shift 8/8) |  | 3w | 2015-10-19 A | 2015-11-06 A |  | 100% |  | 2015-04-01 | 2015-04-09 | 0d |  |  | start no earlier than 2015-10-19 | Fabien Yvan Vincent [50%]; Aurelien Benjamin Dodard [20%] | 84h | 84h | 70,000 | 70,000 |  |
| 161 | 1.2.1.3.6 | Filter unit connection |  | 1d | 2015-07-06 A | 2015-07-06 A |  | 100% |  |  |  |  |  |  | start no earlier than 2015-07-06 | Fabien Yvan Vincent [50%]; Aurelien Benjamin Dodard [20%] | 5.6h | 5.6h | 500 | 500 |  |
| 162 | 1.2.1.3.7 | External barracks connecting (light and power) |  | 1w | 2015-06-01 A | 2015-06-05 A |  | 100% |  |  |  |  |  |  | start no earlier than 2015-06-01 | Fabien Yvan Vincent [50%]; Aurelien Benjamin Dodard [20%] | 28h | 28h | 3,000 | 3,000 |  |
| 163 | 1.2.1.3.8 | Cabling between cabinet to future cutting cell |  | 1w | 2017-11-24 | 2017-11-30 | 92FF |  |  | 2016-10-18 | 2016-10-24 | 0d | 1286d |  |  | Miriam Munoz Codoceo [10%]; Aurelien Benjamin Dodard [20%] | 12h |  | 15,000 |  |  |
| 164 | 1.2.1.3.9 | Transformer installation | milestone | 3w | 2016-06-06 A | 2016-06-24 A |  | 100% |  |  |  |  |  |  | start no earlier than 2016-06-06 | Miriam Munoz Codoceo [50%] | 60h | 60h | 40,000 | 40,000 |  |
| 165 | 1.2.1.3.10 | TGBT (bldg 284) installation | milestone | 3w | 2016-09-12 | 2016-09-30 |  |  |  |  |  |  | 1574d |  | start no earlier than 2016-09-12 | Miriam Munoz Codoceo [50%] | 60h |  | 75,000 |  |  |
| 166 | 1.2.1.3.11 | 18 kV Line | milestone | 3w | 2016-06-20 A | 2016-07-08 A | 164FS-1w | 100% |  |  |  |  |  |  | start no earlier than 2016-05-09 | Miriam Munoz Codoceo [30%] | 36h | 36h | 83,000 | 83,000 | EMTE |
| 167 | 1.2.1.3.12 | Installation of the cabinet in the dedicated room in b. 184 |  | 2d | 2017-01-18 A | 2017-01-19 A | 217 | 100% |  |  |  |  |  |  |  |  |  |  |  |  |  |
| 168 | 1.2.1.3.13 | Inclineurs feeding |  | 3d | 2016-05-09 | 2016-05-11 |  |  |  |  |  |  | 1674d |  | start no earlier than 2016-05-09 |  |  |  | 2,800 |  |  |
| 169 | 1.2.1.3.14 | Bldg 284 kitchen |  | 1w | 2016-06-06 A | 2016-06-10 A | 145 | 100% |  |  |  |  |  |  |  |  |  |  | 3,700 | 3,700 |  |
| 170 | 1.2.1.3.15 | Installation |  | 20d | 2017-03-15 A | 2017-04-12 |  | 79% | 4.24d |  |  |  | 1446.5d |  |  |  |  |  |  |  |  |
| 175 | 1.2.1.3.16 | Ligthing and emerg. Lighting complement (dead end galleries) |  | 2w | 2017-03-23 A | 2017-04-06 |  | 50% | 1w |  |  |  | 1450.5d |  |  | Miriam Munoz Codoceo [10%]; Aurelien Benjamin Dodard [20%] | 24h | 12h | 1,900 | 950 |  |
| 176 | 1.2.1.3.17 | Powering of Crocodile area |  | 3d | 2017-03-23 A | 2017-03-28 A |  | 100% |  |  |  |  |  |  |  | Miriam Munoz Codoceo [10%]; Aurelien Benjamin Dodard [20%] | 7.2h | 7.2h |  |  |  |
| 177 | 1.2.1.3.18 | Old canalis decommission |  | 3d | 2017-03-28 A | 2017-03-31 A | 176 | 100% |  |  |  |  |  |  |  | Miriam Munoz Codoceo [10%]; Aurelien Benjamin Dodard [20%] | 7.2h | 7.2h |  |  |  |
| 178 | 1.2.1.3.19 | Global power cut | milestone | 0.6w | 2017-02-16 A | 2017-02-20 A |  | 100% |  |  |  |  |  |  | finish no earlier than 2017-02-20 |  |  |  |  |  |  |
| 179 | 1.2.1.3.20 | Pulling cables in the trench |  | 2d | 2017-02-13 A | 2017-02-14 A | 151 | 100% |  |  |  |  |  |  |  |  |  |  |  |  |  |
| 180 | 1.2.1.3.21 | Acceptance and inspection |  | 1w | 2017-12-04 | 2017-12-08 | 182 |  |  |  |  |  | 1280d |  |  | Miriam Munoz Codoceo [10%]; Aurelien Benjamin Dodard [20%] | 12h |  |  |  |  |
| 181 | 1.2.1.3.22 | Connections and powering |  | 8w | 2017-08-21 | 2017-10-16 |  |  |  |  |  |  | 1319d |  | start no earlier than 2017-08-21 |  |  |  | 40,000 |  |  |
| 182 | 1.2.1.3.23 | B. 184 installations and connections |  | 6w | 2017-10-23 | 2017-12-01 |  |  |  |  |  |  | 1280d | 0d | start no earlier than 2017-10-23 |  |  |  | 50,000 |  |  |

| ID | WBS | Task | Duration | Start | Finish | Predecessors | Complete | Remaining | Baseline start | Baseline finish | Baseline duration | Total slack | Free slack | Constraint | Resources | Work | Actual work | Cost | Actual cost | Contractor |
| --- | --- | --- | --- | --- | --- | --- | --- | --- | --- | --- | --- | --- | --- | --- | --- | --- | --- | --- | --- | --- |
| 183 | 1.2.1.4 | **HVAC** | 1167.5d | 2015-04-09 A | 2019-12-03 |  | 47% | 621.24d | 2015-05-11 | 2015-07-28 | 0d | 773.5d |  |  |  | 637.2h | 345.6h | 371,500 | 81,000 |  |
| 184 | 1.2.1.4.1 | Scaffolding mounting + provisional plate-forme in the hole | 1.7w | 2015-05-06 A | 2015-05-27 A |  | 100% |  |  |  |  |  |  | finish no earlier than 2015-05-27 | EXT | 68h | 68h | 6,000 | 6,000 |  |
| 185 | 1.2.1.4.2 | Filter unit duct for exhaust and stack installation (chimeny) 1st phase (upper part) | 4d | 2015-06-22 A | 2015-06-25 A |  | 100% |  | 2015-06-24 | 2015-06-30 | 0d |  |  | start no earlier than 2015-05-18 | Franck Audinet [20%]; Aurelien Benjamin Dodard [20%]; EXT [20%] | 31.2h | 31.2h | 10,000 | 10,000 |  |
| 186 | 1.2.1.4.3 | Filter unit duct for exhaust and stack installation (chimeny) 2nd phase (down part) | 2d | 2015-06-25 A | 2015-06-26 A | 185FS-1d | 100% |  |  |  |  |  |  |  | Franck Audinet [20%]; Aurelien Benjamin Dodard [20%]; EXT [20%] | 9.6h | 9.6h | 5,000 | 5,000 |  |
| 187 | 1.2.1.4.4 | Scaffolding dismounting | 1d | 2015-06-25 A | 2015-06-25 A | 185SS | 100% |  |  |  |  |  |  | start no earlier than 2015-06-25 | Franck Audinet [20%]; Aurelien Benjamin Dodard [20%]; EXT [20%] | 4.8h | 4.8h | 500 | 500 |  |
| 188 | 1.2.1.4.5 | Duct connections between press-shear machine and filter unit + exhaust and stack in the cavern | 2d | 2015-06-25 A | 2015-06-26 A | 186FF | 100% |  | 2015-06-24 | 2015-06-30 | 0d |  |  |  | Franck Audinet [20%]; Aurelien Benjamin Dodard [20%]; CE draugthsman [20%] | 9.6h | 9.6h | 6,000 | 6,000 |  |
| 189 | 1.2.1.4.6 | Last connections machine/filter unit/ducts | 3d | 2015-07-01 A | 2015-07-03 A |  | 100% |  |  |  |  |  |  | start no earlier than 2015-07-01 | Franck Audinet [20%]; Aurelien Benjamin Dodard [20%]; CE draugthsman [20%] | 14.4h | 14.4h | 500 | 500 |  |
| 190 | 1.2.1.4.7 | VMS connection | 2d | 2015-07-27 A | 2015-07-28 A |  | 100% |  |  |  |  |  |  | start no earlier than 2015-07-27 | DGS/SEE; Aurelien Benjamin Dodard [50%] | 24h | 24h | 2,000 | 2,000 |  |
| 191 | 1.2.1.4.8 | Compressed air (bldg 184 part) | 1w | 2015-06-08 A | 2015-06-12 A |  | 100% |  | 2015-05-11 | 2015-05-26 | 0d |  |  | start no earlier than 2015-06-08 | Franck Audinet [20%]; Aurelien Benjamin Dodard [20%] | 16h | 16h | 12,000 | 12,000 |  |
| 192 | 1.2.1.4.9 | Compressed air (cavern) | 1w | 2015-06-08 A | 2015-06-12 |  | 90% | 0.1w | 2015-05-11 | 2015-05-26 | 0d | 1897d |  | start no earlier than 2015-06-08 | Franck Audinet [20%]; Aurelien Benjamin Dodard [20%] | 16h | 14.4h | 5,000 | 4,500 |  |
| 193 | 1.2.1.4.10 | Compressed air (SHERPA) | 8.4w | 2015-07-06 A | 2015-09-01 A | 86 | 100% |  | 2015-05-11 | 2015-05-26 | 0d |  |  | start no earlier than 2015-06-08 | Franck Audinet [20%]; Aurelien Benjamin Dodard [20%] | 16h | 16h | 1,500 | 1,500 |  |
| 194 | 1.2.1.4.11 | Compressed air flexible connection (SHERPA) | 1d | 2015-09-02 | 2015-09-02 | 193 |  |  |  |  |  | 1839d |  |  | Franck Audinet [20%]; Aurelien Benjamin Dodard [20%] | 3.2h |  |  |  |  |
| 195 | 1.2.1.4.12 | Ducts dismantling (4 of 8) | 2w | 2015-11-09 A | 2015-11-20 A | 160 | 100% |  | 2015-06-24 | 2015-07-07 | 0d |  |  | start no earlier than 2015-10-07 | Franck Audinet [20%]; Aurelien Benjamin Dodard [20%] | 32h | 32h | 25,000 | 25,000 |  |
| 196 | 1.2.1.4.13 | Ducts dismantling (4 left) | 3w | 2017-05-08 | 2017-05-29 |  |  |  | 2015-06-24 | 2015-07-07 | 0d | 1417d |  | start no earlier than 2017-05-07 | Franck Audinet [20%]; Aurelien Benjamin Dodard [20%] | 48h |  | 15,000 |  |  |
| 197 | 1.2.1.4.14 | Bldg 184 - unit dismantling (access ramp) | 3d | 2015-09-28 A | 2015-09-30 A |  | 100% |  |  |  |  |  |  | start no earlier than 2015-09-28 | Franck Audinet [20%]; Aurelien Benjamin Dodard [20%] | 9.6h | 9.6h | 6,500 | 6,500 |  |
| 198 | 1.2.1.4.15 | External barracks connecting (drinking water-ventil) | 1w | 2015-08-24 A | 2015-08-28 A | 126SS, 125SS | 100% |  |  |  |  |  |  |  | Franck Audinet [20%]; Aurelien Benjamin Dodard [20%] | 16h | 16h | 1,500 | 1,500 |  |
| 199 | 1.2.1.4.16 | Asbestos diag (campagne) | 2w | 2015-04-09 A | 2015-04-22 A |  | 100% |  | 2015-04-13 | 2015-05-27 | 0d |  |  | start no earlier than 2015-04-09 | HSE/SEE | 80h | 80h |  |  |  |
| 200 | 1.2.1.4.17 | Underground galleries works (incl. vertical access to ventil room) | 5w | 2019-02-12 | 2019-03-18 | 412 |  |  | 2016-04-29 | 2016-05-09 | 0d | 773.5d | 0d |  | Franck Audinet [30%] | 60h |  |  |  | IT |
| 201 | 1.2.1.4.18 | Tunnel works (fans, grids etc. including hose reels) | 2.5w | 2019-03-05 | 2019-03-21 | 202SS |  |  | 2016-05-10 | 2016-05-17 | 0d | 773.5d | 0d |  | Franck Audinet [30%] | 30h |  | 25,000 |  | IT |
| 202 | 1.2.1.4.19 | Ventilation room (over the tunnel) works | 2w | 2019-03-05 | 2019-03-18 | 200SS+3w |  |  | 2016-05-18 | 2016-05-24 | 0d | 773.5d | 0d |  | Franck Audinet [30%] | 24h |  | 250,000 |  | IT |
| 203 | 1.2.1.4.20 | Works outside (surface - above ventil room) | 4w | 2019-02-12 | 2019-03-11 | 200SS |  |  | 2016-05-18 | 2016-05-24 | 0d | 964d |  |  | Franck Audinet [30%] | 48h |  |  |  | IT |
| 204 | 1.2.1.4.21 | Partial acceptance and inspection ISR4 only | 2d | 2019-03-21 | 2019-03-25 | 201 |  |  |  |  |  | 773.5d | 0d |  | Franck Audinet [30%] | 4.8h |  |  |  |  |
| 205 | 1.2.1.4.22 | Partial acceptance and inspection ISR4 + ISR5 | 2w | 2019-03-25 | 2019-04-08 | 204 |  |  |  |  |  | 773.5d | 0d |  | Franck Audinet [30%] | 24h |  |  |  |  |
| 206 | 1.2.1.4.23 | GLOBAL HVAC acceptance and inspection | 4w | 2019-11-05 | 2019-12-03 | 353 |  |  | 2016-06-08 | 2016-06-14 | 0d | 773.5d |  |  | Franck Audinet [30%] | 48h |  |  |  |  |

| ID | WBS | Task | Type | Duration | Start | Finish | Predecessors | Complete | Remaining | Baseline start | Baseline finish | Baseline duration | Total slack | Free slack | Constraint | Resources | Work | Actual work | Cost | Actual cost | Contractor |
| --- | --- | --- | --- | --- | --- | --- | --- | --- | --- | --- | --- | --- | --- | --- | --- | --- | --- | --- | --- | --- | --- |
| 207 | 1.2.1.5 | **Fire detec.** |  | 792d | 2015-07-20 A | 2018-09-28 |  | 67% | 264d | 2015-07-01 | 2015-07-14 | 0d | 1080d |  |  |  | 192h | 192h | 104,700 | 74,700 |  |
| 208 | 1.2.1.5.1 | System for press-shear machine and filter unit |  | 2w | 2015-07-20 A | 2015-07-31 A | 87FS+1w | 100% |  | 2015-07-01 | 2015-07-07 | 0d |  |  | start no earlier than 2015-06-16 | Denis Raffourt; Aurelien Benjamin Dodard [20%] | 96h | 96h | 73,000 | 73,000 |  |
| 209 | 1.2.1.5.2 | Wiring cabinet |  | 2w | 2015-07-20 A | 2015-07-31 A | 208FF | 100% |  | 2015-07-08 | 2015-07-14 | 0d |  |  |  | Denis Raffourt; Aurelien Benjamin Dodard [20%] | 96h | 96h | 1,700 | 1,700 |  |
| 210 | 1.2.1.5.3 | Detection near fire sources |  | 2w | 2018-09-17 | 2018-09-28 | 269 |  |  |  |  |  | 1080d |  |  |  |  |  | 30,000 |  |  |
| 211 | 1.2.1.6 | **IT/CS** |  | 640d | 2015-05-05 A | 2017-12-04 |  | 82% | 116.36d | 2015-03-17 | 2015-04-02 | 0d | 1284d |  |  |  | 86.4h | 67.2h | 8,100 | 8,100 |  |
| 212 | 1.2.1.6.1 | Press-shear machine cabling (after cabinet) |  | 2d | 2015-05-05 A | 2015-05-06 A | 157 | 100% |  | 2015-04-01 | 2015-04-02 | 0d |  |  |  | Leszek Borakiewicz; Aurelien Benjamin Dodard [20%] | 19.2h | 19.2h | 5,400 | 5,400 |  |
| 213 | 1.2.1.6.2 | Filter unit, access etc. cabling (after cabinet) |  | 2d | 2015-06-18 A | 2015-06-19 A | 85FF-1w | 100% |  | 2015-03-17 | 2015-03-19 | 0d |  |  |  | Leszek Borakiewicz; Aurelien Benjamin Dodard [20%] | 19.2h | 19.2h |  |  |  |
| 214 | 1.2.1.6.3 | GSM cable moving behind filter unit |  | 1d | 2015-06-26 A | 2015-06-26 A | 85SS | 100% |  |  |  |  |  |  |  | Leszek Borakiewicz; Aurelien Benjamin Dodard [20%] | 9.6h | 9.6h |  |  |  |
| 215 | 1.2.1.6.4 | Cutting cell cabling |  | 2d | 2017-12-01 | 2017-12-04 | 92 |  |  |  |  |  | 1284d |  |  | Leszek Borakiewicz; Aurelien Benjamin Dodard [20%] | 19.2h |  |  |  |  |
| 216 | 1.2.1.6.5 | External barracks connecting |  | 2d | 2015-05-20 A | 2015-05-21 A | 222 | 100% |  |  |  |  |  |  |  | Leszek Borakiewicz; Aurelien Benjamin Dodard [20%] | 19.2h | 19.2h |  |  |  |
| 217 | 1.2.1.6.6 | Star point modification in the dedicated room in b. 184 |  | 2d | 2017-01-16 A | 2017-01-17 A |  | 100% |  |  |  |  |  |  | start no earlier than 2017-01-16 |  |  |  | 2,700 | 2,700 |  |
| 218 | 1.2.1.7 | **EN/HE** |  | 582d | 2015-04-13 A | 2017-08-22 A |  | 100% |  | 2015-05-27 | 2016-02-26 | 0d |  |  |  |  | 195.6h | 195.6h | 37,000 | 37,000 |  |
| 219 | 1.2.1.7.1 | Zoning (cabin and machines space) |  | 1w | 2015-07-06 A | 2015-07-10 A |  | 100% |  | 2015-05-27 | 2015-06-02 | 0d |  |  | start no earlier than 2015-07-06 | Helder Lourenco; Aurelien Benjamin Dodard [20%] | 48h | 48h |  |  |  |
| 220 | 1.2.1.7.2 | Containers moving (near CMS zone) |  | 1d | 2015-04-13 A | 2015-04-13 A | 119 | 100% |  |  |  |  |  |  |  | Helder Lourenco; Aurelien Benjamin Dodard [20%] | 9.6h | 9.6h |  |  |  |
| 221 | 1.2.1.7.3 | Blocks moving from CMS zone | manual | 4d | 2015-06-09 A | 2015-06-12 A |  | 100% |  | 2015-06-05 | 2015-06-19 | 0d |  |  |  | Helder Lourenco | 32h | 32h |  |  |  |
| 222 | 1.2.1.7.4 | External barracks transporting (6718 + one in bldg 172) |  | 2d | 2015-05-18 A | 2015-05-19 A |  | 100% |  |  |  |  |  |  | start no earlier than 2015-05-18 | Helder Lourenco; Aurelien Benjamin Dodard [20%] | 19.2h | 19.2h |  |  |  |
| 223 | 1.2.1.7.5 | Electrical feeding line for crane and anticollision syst. |  | 4w | 2017-07-26 A | 2017-08-22 A | 137 | 100% |  | 2016-02-15 | 2016-02-26 | 0d |  |  |  | Helder Lourenco; Aurelien Benjamin Dodard [20%] | 67.2h | 67.2h | 22,000 | 22,000 |  |
| 224 | 1.2.1.7.6 | Bloc removing from filter unit stack |  | 1d | 2015-06-23 A | 2015-06-23 A | 185SS+1d | 100% |  |  |  |  |  |  |  | Helder Lourenco; Aurelien Benjamin Dodard [20%] | 9.6h | 9.6h |  |  |  |
| 225 | 1.2.1.7.7 | Installation of 2 potences |  | 2w | 2016-04-04 A | 2016-04-15 A |  | 100% |  |  |  |  |  |  | start no earlier than 2016-04-04 | Cristiana Colloca [5%]; Aurelien Benjamin Dodard [5%]; Fabien Yvan Vincent [5%]; Helder Lourenco [5%] | 10h | 10h | 15,000 | 15,000 |  |
| 226 | 1.2.1.8 | **BE/ICS** |  | 15d | 2018-10-29 | 2018-11-16 |  |  |  | 2015-06-01 | 2015-06-26 | 0d | 1045d |  |  |  | 24h |  |  |  |  |
| 227 | 1.2.1.8.1 | New access control |  | 3w | 2018-10-29 | 2018-11-16 | 277 |  |  | 2015-06-01 | 2015-06-26 | 0d | 1045d |  | start no earlier than 2016-02-01 | Nino Rama [20%] | 24h |  |  |  |  |
| 229 | 1.2.2 | **ISR 2 (storage area)** |  | 966d | 2015-03-16 A | 2019-01-31 |  | 18% | 793.19d | 2015-03-30 | 2016-06-14 | 0d | 991d |  |  |  | 879.7h | 350.9h | 1,512,600 | 129,600 |  |
| 230 | 1.2.2.1 | ISR 2 Availability | milestone | 1d | 2018-07-02 | 2018-07-02 |  |  |  | 2015-04-07 | 2015-04-07 | 0d | 1144d | 0d | start no earlier than 2018-07-02 |  |  |  |  |  |  |
| 231 | 1.2.2.2 | **Civil engineering** |  | 966d | 2015-03-16 A | 2019-01-31 |  | 27% | 701.45d | 2015-04-08 | 2015-09-29 | 0d | 991d |  |  |  | 405.3h | 166.9h | 556,700 | 90,700 |  |
| 232 | 1.2.2.2.1 | Wall - fire compart. Mounting 1st part |  | 2d | 2015-03-16 A | 2015-03-17 A |  | 100% |  | 2015-04-08 | 2015-04-14 | 0d |  |  | start no earlier than 2015-03-16 | Aurelien Benjamin Dodard [35%] | 8h | 8h |  |  |  |
| 233 | 1.2.2.2.2 | Wall - fire compart. Mounting 2nd part |  | 3w | 2015-04-27 A | 2015-05-19 A |  | 100% |  |  |  |  |  |  | start no earlier than 2015-04-27 | Aurelien Benjamin Dodard [35%] | 18.5h | 18.5h | 8,500 | 8,500 | Sarvadon |
| 234 | 1.2.2.2.3 | Removal of floor rails (CMS zone) + concrete pooring |  | 3w | 2015-03-18 A | 2015-04-09 A | 232 | 100% |  | 2015-08-03 | 2015-08-07 | 0d |  |  | start no earlier than 2015-03-02 | Aurelien Benjamin Dodard [35%] | 60h | 60h | 29,000 | 29,000 | Dimensione |
| 235 | 1.2.2.2.4 | CMS 3 blocks installation and alignement |  | 1d | 2015-04-24 A | 2015-04-24 A |  | 100% |  |  |  |  |  |  | start no earlier than 2015-04-24 | CMS | 8h | 8h |  |  | Altead |
| 236 | 1.2.2.2.5 | Resin and painting (CMS zone) |  | 2w | 2015-04-27 A | 2015-05-11 A | 235 | 100% |  | 2015-08-10 | 2015-08-14 | 0d |  |  |  | Aurelien Benjamin Dodard [35%] | 40h | 40h | 35,600 | 35,600 | Prezioso |
| 237 | 1.2.2.2.6 | Floor repair (metal rails) |  | 1w | 2018-06-01 | 2018-06-07 |  |  |  | 2015-08-03 | 2015-08-07 | 0d | 1141d | 0d | start no earlier than 2018-06-01 | Aurelien Benjamin Dodard [35%] | 20h |  | 10,000 |  | Dimensione |
| 238 | 1.2.2.2.7 | Drainages and holes sealing |  | 4w | 2018-06-08 | 2018-07-05 | 237 |  |  | 2015-08-03 | 2015-08-07 | 0d | 1141d |  |  | Aurelien Benjamin Dodard [35%] | 56h |  | 50,000 |  | Dimensione |
| 239 | 1.2.2.2.8 | Floor waterproofing |  | 4w | 2019-01-04 | 2019-01-31 | 263 |  |  | 2015-07-13 | 2015-07-31 | 0d | 991d |  | start no earlier than 2018-07-02 | Aurelien Benjamin Dodard [35%] | 50.4h |  | 200,000 |  |  |
| 240 | 1.2.2.2.9 | Painting 1st phase |  | 2w | 2018-07-02 | 2018-07-13 | 254 |  |  | 2015-09-07 | 2015-09-29 | 0d | 1135d |  |  | Aurelien Benjamin Dodard [35%] | 28h |  | 30,000 |  | Prezioso |
| 241 | 1.2.2.2.10 | Painting 2 nd phase |  | 2w | 2018-10-08 | 2018-10-19 | 255 |  |  | 2015-09-07 | 2015-09-29 | 0d | 1065d |  |  | Aurelien Benjamin Dodard [35%] | 28h |  |  |  | Prezioso |
| 242 | 1.2.2.2.11 | Concrete lintel (all ISR) |  | 1w | 2016-11-14 A | 2016-11-18 A |  | 100% |  |  |  |  |  |  | start no earlier than 2016-11-14 | Cristiana Colloca [10%]; Aurelien Benjamin Dodard [50%] | 24h | 24h | 3,300 | 3,300 |  |
| 243 | 1.2.2.2.12 | Ceiling painting |  | 2w | 2018-06-11 | 2018-06-22 | 254SS+3w |  |  |  |  |  | 1150d |  |  |  |  |  |  |  |  |
| 244 | 1.2.2.2.13 | New door for ventil + 1 fire doors ground level |  | 4w | 2018-07-24 | 2018-08-20 | 29FS+6w |  |  |  |  |  | 1089d | 0d | finish no earlier than 2017-12-22 | Aurelien Benjamin Dodard [35%] | 56h |  | 40,000 |  |  |
| 245 | 1.2.2.2.14 | Grid and gutter repair |  | 3d | 2015-09-24 A | 2015-09-28 A | 140 | 100% |  |  |  |  |  |  | start no earlier than 2015-08-31 | Aurelien Benjamin Dodard [35%] | 8.4h | 8.4h | 9,000 | 9,000 | Scrasa |
| 246 | 1.2.2.2.15 | Fire wall and floor repairs ground leveL |  | 2w | 2018-07-10 | 2018-07-24 | 244SF |  |  |  |  |  | 1129d |  |  |  |  |  | 20,000 |  |  |
| 247 | 1.2.2.2.16 | Corbels repair |  | 4w | 2018-05-09 | 2018-06-05 | 273 |  |  |  |  |  | 1123d | 0d | start no earlier than 2018-03-19 |  |  |  | 6,000 |  | Dimensione |
| 248 | 1.2.2.2.17 | Casquettes (all ISR) |  | 3w | 2015-06-05 A | 2015-06-25 A |  | 100% |  |  |  |  |  |  | start no earlier than 2015-06-05 |  |  |  | 5,300 | 5,300 |  |
| 249 | 1.2.2.2.18 | Smoke barriers |  | 2w | 2018-12-14 | 2018-12-27 | 267 |  |  |  |  |  | 1001d | 0d |  |  |  |  | 15,000 |  |  |
| 250 | 1.2.2.2.19 | Stairs replacement |  | 1w | 2018-04-02 | 2018-04-06 | 28FS+5w |  |  |  |  |  | 1195d | 0d | start no earlier than 2017-10-02 |  |  |  | 30,000 |  |  |
| 251 | 1.2.2.2.20 | Access modif. & waterpr for retention basin (and fire walls) |  | 4w | 2018-08-21 | 2018-09-17 | 244 |  |  |  |  |  | 1089d |  | start no earlier than 2018-04-30 |  |  |  | 50,000 |  |  |
| 252 | 1.2.2.2.21 | Civil eng works for HVAC |  | 3w | 2018-07-17 | 2018-08-06 | 30FS+5w |  |  |  |  |  | 1044d | 0d | start no earlier than 2018-04-30 |  |  |  | 15,000 |  |  |

| ID | WBS | Task | Duration | Start | Finish | Predecessors | Complete | Remaining | Baseline start | Baseline finish | Baseline duration | Total slack | Free slack | Constraint | Resources | Work | Actual work | Cost | Actual cost | Contractor |
| --- | --- | --- | --- | --- | --- | --- | --- | --- | --- | --- | --- | --- | --- | --- | --- | --- | --- | --- | --- | --- |
| 253 | 1.2.2.3 | **Elec** | 100d | 2018-05-21 | 2018-10-05 |  |  |  | 2016-01-27 | 2016-02-23 | 0d | 1045d |  |  |  |  |  | 140,000 |  |  |
| 254 | 1.2.2.3.1 | Removals | 6w | 2018-05-21 | 2018-06-29 |  |  |  |  |  |  | 1045d | 0d | start no earlier than 2018-05-21 |  |  |  | 20,000 |  |  |
| 255 | 1.2.2.3.2 | Installations | 14w | 2018-07-02 | 2018-10-05 | 254 |  |  |  |  |  | 1045d | 0d |  |  |  |  | 120,000 |  |  |
| 256 | 1.2.2.4 | **HVAC** | 892d | 2015-06-12 A | 2019-01-10 |  | 25% | 670.63d | 2015-04-13 | 2016-06-14 | 0d | 1006d |  |  |  | 394.4h | 184h | 644,900 | 38,900 |  |
| 257 | 1.2.2.4.1 | Asbestos diag (campagne) | 4w | 2015-06-12 A | 2015-07-09 A |  | 100% |  | 2015-04-13 | 2015-05-27 | 0d |  |  | start no earlier than 2015-06-12 | DGS/SEE | 160h | 160h |  |  |  |
| 258 | 1.2.2.4.2 | Ventil units dismantling V2 | 12d | 2016-06-08 A | 2016-06-23 A | 401 | 100% |  | 2015-07-02 | 2015-07-08 | 0d |  |  |  | Aurelien Benjamin Dodard [20%] | 19.2h | 19.2h | 34,000 | 34,000 | Altead, Ram Power |
| 259 | 1.2.2.4.3 | Ducts dismantling | 1w | 2018-05-14 | 2018-05-21 | 254SF |  |  | 2015-05-28 | 2015-06-03 | 0d | 1174d | 0d | start no earlier than 2017-05-15 | Franck Audinet [30%] | 12h |  | 30,000 |  | Dalkia |
| 260 | 1.2.2.4.4 | Old gas pipe dismounting | 1d | 2018-05-21 | 2018-05-21 | 259 |  |  |  |  |  | 1174d |  | start no earlier than 2017-02-20 | Aurelien Benjamin Dodard [20%] | 1.6h |  | 1,000 |  |  |
| 261 | 1.2.2.4.5 | Ventil units dismantling V1 | 3w | 2018-06-11 | 2018-06-29 |  |  |  |  |  |  | 1145d |  | start no earlier than 2018-06-11 |  |  |  | 25,000 |  |  |
| 262 | 1.2.2.4.6 | EN/CV duct dismantling (access) | 2d | 2016-10-27 A | 2016-10-28 A |  | 100% |  | 2015-05-28 | 2015-06-03 | 0d |  |  | start no earlier than 2017-10-30 | Franck Audinet [30%] | 4.8h | 4.8h | 4,900 | 4,900 | EN/CV |
| 263 | 1.2.2.4.7 | Underground galleries (dry raiser) + tunnel works | 5w | 2018-11-30 | 2019-01-03 | 62FS+24w |  |  | 2016-04-29 | 2016-05-09 | 0d | 773.5d | 0d |  | Franck Audinet [30%] | 60h |  | 550,000 |  | IT |
| 264 | 1.2.2.4.8 | Ventilation room (over the tunnel) works (including V1) | 3w | 2018-12-21 | 2019-01-10 | 263SS+3w |  |  | 2016-05-18 | 2016-05-24 | 0d | 1006d |  |  | Franck Audinet [30%] | 36h |  |  |  | IT |
| 265 | 1.2.2.4.9 | Works outside (surface - above ventil room) | 6w | 2018-11-30 | 2019-01-10 | 263SS |  |  | 2016-05-18 | 2016-05-24 | 0d | 1006d |  |  | Franck Audinet [30%] | 72h |  |  |  | IT |
| 266 | 1.2.2.4.10 | Control & regulation | 2w | 2018-11-30 | 2018-12-13 | 263SS |  |  | 2016-05-18 | 2016-05-24 | 0d | 773.5d | 0d |  | Franck Audinet [30%] | 24h |  |  |  | IT |
| 267 | 1.2.2.4.11 | Partial acceptance and inspection ISR2 only | 2d | 2018-12-12 | 2018-12-13 | 266FF |  |  | 2016-06-08 | 2016-06-14 | 0d | 773.5d | 0d |  | Franck Audinet [30%] | 4.8h |  |  |  |  |
| 268 | 1.2.2.5 | **Fire detec.** | 94d | 2018-09-10 | 2019-01-17 |  |  |  | 2016-02-24 | 2016-03-08 | 0d | 1001d |  |  |  | 32h |  | 116,000 |  |  |
| 269 | 1.2.2.5.1 | Old system dismantling & new system | 1w | 2018-09-10 | 2018-09-14 |  |  |  | 2016-02-24 | 2016-03-01 | 0d | 1065d | 0d | start no earlier than 2018-09-10 | Denis Raffourt [20%] | 8h |  |  |  |  |
| 270 | 1.2.2.5.2 | New system commissioning | 3w | 2018-09-17 | 2018-10-05 | 269 |  |  | 2016-03-02 | 2016-03-08 | 0d | 1065d | 0d |  | Denis Raffourt [20%] | 24h |  | 40,000 |  |  |
| 271 | 1.2.2.5.3 | Sprinkler system | 3w | 2018-12-28 | 2019-01-17 | 249 |  |  |  |  |  | 1001d |  |  |  |  |  | 76,000 |  |  |
| 272 | 1.2.2.6 | **EN/HE** | 50d | 2018-05-02 | 2018-07-10 |  |  |  | 2015-09-07 | 2015-09-21 | 0d | 1123d |  |  |  | 24h |  | 55,000 |  |  |
| 273 | 1.2.2.6.1 | Survey | 1w | 2018-05-02 | 2018-05-08 |  |  |  |  |  |  | 1123d | 0d | start no earlier than 2018-05-02 |  |  |  |  |  |  |
| 274 | 1.2.2.6.2 | Rails realignement (if survey non satisf) + weldings | 3w | 2018-06-06 | 2018-06-26 | 247 |  |  | 2015-09-07 | 2015-09-21 | 0d | 1123d | 0d |  | Helder Lourenco [20%] | 24h |  | 40,000 |  |  |
| 275 | 1.2.2.6.3 | Electrical feeding line (TBC) | 2w | 2018-06-27 | 2018-07-10 | 274 |  |  |  |  |  | 1138d |  | start no earlier than 2016-08-01 |  |  |  | 15,000 |  |  |
| 276 | 1.2.2.7 | **BE/ICS** | 15d | 2018-10-08 | 2018-10-26 |  |  |  | 2015-06-01 | 2015-06-26 | 0d | 1045d |  |  |  | 24h |  |  |  |  |
| 277 | 1.2.2.7.1 | New access control | 3w | 2018-10-08 | 2018-10-26 | 255 |  |  | 2015-06-01 | 2015-06-26 | 0d | 1045d | 0d | start no earlier than 2017-06-19 | Nino Rama [20%] | 24h |  |  |  |  |

| ID | WBS | Task | Type | Duration | Start | Finish | Predecessors | Complete | Remaining | Baseline start | Baseline finish | Baseline duration | Total slack | Free slack | Constraint | Resources | Work | Actual work | Cost | Actual cost | Building | Contractor |
| --- | --- | --- | --- | --- | --- | --- | --- | --- | --- | --- | --- | --- | --- | --- | --- | --- | --- | --- | --- | --- | --- | --- |
| 278 | 1.2.3 | **T2 parallel gallery** |  | 471d | 2017-03-29 A | 2019-02-07 |  | 12% | 412.61d | 2015-04-07 | 2016-06-07 | 0d | 986d |  |  |  | 202h | 42h | 140,000 | 85,000 |  |  |
| 279 | 1.2.3.1 | T2 Availability | milestone | 1d | 2018-07-02 | 2018-07-02 | 230SS |  |  | 2015-04-07 | 2015-04-07 | 0d | 1144d |  |  |  |  |  |  |  |  |  |
| 280 | 1.2.3.2 | **Civil engineering** |  | 471d | 2017-03-29 A | 2019-02-07 |  | 33% | 314d |  |  |  | 986d |  |  |  | 70h | 42h | 130,000 | 85,000 |  |  |
| 281 | 1.2.3.2.1 | Waterproofing underground galleries and fire walls |  | 3w | 2017-03-29 A | 2017-04-20 A | 428 | 100% |  | 2015-06-29 | 2015-07-10 | 0d |  |  |  | Aurelien Benjamin Dodard [35%] | 42h | 42h | 85,000 | 85,000 |  |  |
| 282 | 1.2.3.2.2 | Fire walls & other works in underground |  | 4w | 2018-09-03 | 2018-09-28 |  |  |  |  |  |  | 1075d | 0d | start no earlier than 2018-09-03 |  |  |  | 25,000 |  | 2PG |  |
| 283 | 1.2.3.2.3 | Doors for access control |  | 1w | 2018-10-01 | 2018-10-05 | 282 |  |  |  |  |  | 1075d |  | start no earlier than 2016-05-30 | Aurelien Benjamin Dodard [35%] | 14h |  | 15,000 |  | 2PG |  |
| 284 | 1.2.3.2.4 | Filling holes between gallerie and tunnel |  | 1w | 2019-02-01 | 2019-02-07 | 289 |  |  |  |  |  | 986d |  |  | Aurelien Benjamin Dodard [35%] | 14h |  | 5,000 |  | 2PG |  |
| 285 | 1.2.3.3 | **Elec** |  | 10d | 2018-10-08 | 2018-10-19 |  |  |  |  |  |  | 1065d |  |  |  | 12h |  |  |  | 2PG |  |
| 286 | 1.2.3.3.1 | Installation of new cable trays |  | 1w | 2018-10-08 | 2018-10-12 | 255 |  |  |  |  |  | 1065d | 0d | start no earlier than 2016-11-28 |  |  |  |  |  | 2PG |  |
| 287 | 1.2.3.3.2 | Cabling & lighting |  | 1w | 2018-10-15 | 2018-10-19 | 286 |  |  |  |  |  | 1065d |  |  | Miriam Munoz Codoceo [30%] | 12h |  |  |  | 2PG |  |
| 288 | 1.2.3.4 | **HVAC** |  | 45d | 2018-11-30 | 2019-01-31 |  |  |  | 2016-05-25 | 2016-06-07 | 0d | 991d |  |  |  | 96h |  |  |  | 2PG |  |
| 289 | 1.2.3.4.1 | Gallery works (ducts, grids etc.) |  | 4w | 2019-01-04 | 2019-01-31 | 263 |  |  | 2016-05-10 | 2016-05-17 | 0d | 986d | 0d |  | Franck Audinet [30%] | 48h |  |  |  | 2PG | IT |
| 290 | 1.2.3.4.2 | Works outside (surface) |  | 4w | 2018-11-30 | 2018-12-27 | 263SS |  |  | 2016-05-18 | 2016-05-24 | 0d | 1016d |  |  | Franck Audinet [30%] | 48h |  |  |  | 2PG | IT |
| 291 | 1.2.3.5 | **Fire detec.** |  | 10d | 2018-10-08 | 2018-10-19 |  |  |  | 2016-03-09 | 2016-03-15 | 0d | 1065d |  |  |  |  |  | 10,000 |  | 2PG |  |
| 292 | 1.2.3.5.1 | New system installation & commissioning |  | 2w | 2018-10-08 | 2018-10-19 | 270 |  |  | 2016-03-09 | 2016-03-15 | 0d | 1065d |  |  |  |  |  | 10,000 |  | 2PG |  |
| 293 | 1.2.3.6 | **BE/ICS** |  | 15d | 2018-10-29 | 2018-11-16 |  |  |  | 2015-06-01 | 2015-06-26 | 0d | 1045d |  |  |  | 24h |  |  |  |  |  |
| 294 | 1.2.3.6.1 | New access control |  | 3w | 2018-10-29 | 2018-11-16 | 277 |  |  | 2015-06-01 | 2015-06-26 | 0d | 1045d |  | start no earlier than 2017-06-19 | Nino Rama [20%] | 24h |  |  |  |  |  |
| 296 | 1.2.4 | **ISR 3 (storage area) LEFT SIDE** |  | 1448d | 2017-04-11 A | 2022-11-18 |  | 1% | 1433.66d | 2015-03-30 | 2016-06-14 | 0d | 0d |  |  |  | 285.2h | 7h | 609,700 | 18,000 | 3L |  |
| 297 | 1.2.4.1 | ISR3 L Availability | milestone | 1d | 2022-07-04 | 2022-07-04 |  |  |  | 2015-04-07 | 2015-04-07 | 0d | 74d | 0d | start no earlier than 2022-07-04 |  |  |  |  |  | 3L |  |
| 298 | 1.2.4.2 | **Civil engineering** |  | 1448d | 2017-04-11 A | 2022-11-18 |  | 2% | 1418.45d | 2015-04-08 | 2015-09-29 | 0d | 0d |  |  |  | 168.4h | 7h | 355,000 | 18,000 | 3L |  |
| 299 | 1.2.4.2.1 | Floor repair (metal rails) |  | 1w | 2022-07-05 | 2022-07-11 | 297 |  |  | 2015-08-03 | 2015-08-07 | 0d | 74d | 0d | start no earlier than 2018-06-01 | Aurelien Benjamin Dodard [35%] | 20h |  | 5,000 |  | 3L | Dimensione |
| 300 | 1.2.4.2.2 | Drainages and holes sealing |  | 4w | 2022-07-12 | 2022-08-08 | 299 |  |  | 2015-08-03 | 2015-08-07 | 0d | 74d |  |  | Aurelien Benjamin Dodard [35%] | 56h |  | 50,000 |  | 3L | Dimensione |
| 301 | 1.2.4.2.3 | Floor waterproofing |  | 4w | 2022-10-24 | 2022-11-18 | 322 |  |  | 2015-07-13 | 2015-07-31 | 0d | 0d |  | start no earlier than 2018-07-02 | Aurelien Benjamin Dodard [35%] | 50.4h |  | 160,000 |  | 3L |  |
| 302 | 1.2.4.2.4 | Painting 1st phase |  | 1w | 2022-07-25 | 2022-07-29 | 310 |  |  | 2015-09-07 | 2015-09-29 | 0d | 80d |  |  | Aurelien Benjamin Dodard [35%] | 14h |  | 28,000 |  | 3L | Prezioso |
| 303 | 1.2.4.2.5 | Painting 2 nd phase |  | 1w | 2022-09-12 | 2022-09-16 | 311 |  |  | 2015-09-07 | 2015-09-29 | 0d | 45d |  |  | Aurelien Benjamin Dodard [35%] | 14h |  |  |  | 3L | Prezioso |
| 304 | 1.2.4.2.6 | New door for ventil (replacement) incl. fire boxes |  | 1w | 2017-04-11 A | 2017-09-21 | 389 | 50% | 0.5w |  |  |  | 1336d |  |  | Aurelien Benjamin Dodard [35%] | 14h | 7h | 36,000 | 18,000 | 3L |  |
| 305 | 1.2.4.2.7 | Corbels repair |  | 1.5w | 2018-06-15 | 2018-06-26 | 336 |  |  |  |  |  | 1148d |  |  |  |  |  | 5,000 |  | 3L | Dimensione |
| 306 | 1.2.4.2.8 | New fire wall & door |  | 4w | 2018-03-12 | 2018-04-06 |  |  |  |  |  |  | 1145d | 0d | start no earlier than 2018-03-12 |  |  |  | 40,000 |  | 3L |  |
| 307 | 1.2.4.2.9 | Closing floor plates (ISR3, ISR7) |  | 4w | 2017-07-24 | 2017-08-18 |  |  |  |  |  |  | 1359d |  | start no earlier than 2017-07-24 |  |  |  | 16,000 |  | 3L |  |
| 308 | 1.2.4.2.10 | Civil eng works for HVAC |  | 3w | 2018-08-28 | 2018-09-17 | 154 |  |  |  |  |  | 1044d | 0d |  |  |  |  | 15,000 |  | 3L |  |

| ID | WBS | Task | Type | Duration | Start | Finish | Predecessors | Complete | Remaining | Baseline start | Baseline finish | Baseline duration | Total slack | Free slack | Constraint | Resources | Work | Actual work | Cost | Actual cost | Building | Contractor |
| --- | --- | --- | --- | --- | --- | --- | --- | --- | --- | --- | --- | --- | --- | --- | --- | --- | --- | --- | --- | --- | --- | --- |
| 309 | 1.2.4.3 | **Elec** |  | 50d | 2022-07-04 | 2022-09-09 |  |  |  | 2016-01-27 | 2016-02-23 | 0d | 0d |  |  |  |  |  | 70,000 |  | 3L |  |
| 310 | 1.2.4.3.1 | Removals |  | 3w | 2022-07-04 | 2022-07-22 |  |  |  |  |  |  | 0d |  | start no earlier than 2022-07-04 |  |  |  | 10,000 |  | 3L |  |
| 311 | 1.2.4.3.2 | Installations |  | 7w | 2022-07-25 | 2022-09-09 | 310 |  |  |  |  |  | 0d |  |  |  |  |  | 60,000 |  | 3L |  |
| 312 | 1.2.4.4 | **HVAC** |  | 722.5d | 2019-09-26 | 2022-07-04 |  |  |  | 2015-04-13 | 2016-06-14 | 0d | 99d |  |  |  | 44.8h |  | 146,000 |  | 3L |  |
| 313 | 1.2.4.4.1 | Ducts dismantling |  | 3d | 2022-06-29 | 2022-07-04 | 310SF |  |  | 2015-05-28 | 2015-06-03 | 0d | 99d | 0d |  | Franck Audinet [30%] | 7.2h |  | 20,000 |  | 3L | Dalkia |
| 314 | 1.2.4.4.2 | Old gas pipe dismounting |  | 1d | 2022-07-04 | 2022-07-04 | 313 |  |  |  |  |  | 99d |  |  | Aurelien Benjamin Dodard [20%] | 1.6h |  | 1,000 |  | 3L |  |
| 315 | 1.2.4.4.3 | Tunnel works (fans, grids etc. including dry riser) |  | 3w | 2019-09-26 | 2019-10-17 | 348 |  |  | 2016-05-10 | 2016-05-17 | 0d | 773.5d | 0d |  | Franck Audinet [30%] | 36h |  | 125,000 |  | 3L | IT |
| 316 | 1.2.4.5 | **Fire detec.** |  | 20d | 2022-09-12 | 2022-10-07 |  |  |  | 2016-02-24 | 2016-03-08 | 0d | 30d |  |  |  | 32h |  | 13,700 |  | 3L |  |
| 317 | 1.2.4.5.1 | Old system dismantling & new system |  | 1w | 2022-09-12 | 2022-09-16 | 311 |  |  | 2016-02-24 | 2016-03-01 | 0d | 30d | 0d |  | Denis Raffourt [20%] | 8h |  |  |  | 3L |  |
| 318 | 1.2.4.5.2 | New system commissioning |  | 3w | 2022-09-19 | 2022-10-07 | 317 |  |  | 2016-03-02 | 2016-03-08 | 0d | 30d |  |  | Denis Raffourt [20%] | 24h |  | 13,700 |  | 3L |  |
| 319 | 1.2.4.6 | **EN/HE** |  | 30d | 2022-09-12 | 2022-10-21 |  |  |  | 2015-09-07 | 2015-09-21 | 0d | 0d |  |  |  | 24h |  | 25,000 |  | 3L |  |
| 320 | 1.2.4.6.1 | Survey |  | 1w | 2022-09-12 | 2022-09-16 | 311 |  |  |  |  |  | 0d |  |  |  |  |  |  |  | 3L |  |
| 321 | 1.2.4.6.2 | Rails realignement (if survey non satisf) |  | 3w | 2022-09-19 | 2022-10-07 | 320 |  |  | 2015-09-07 | 2015-09-21 | 0d | 0d |  |  | Helder Lourenco [20%] | 24h |  | 10,000 |  | 3L |  |
| 322 | 1.2.4.6.3 | Electrical feeding line (TBC) |  | 2w | 2022-10-10 | 2022-10-21 | 321 |  |  |  |  |  | 0d |  | start no earlier than 2016-08-01 |  |  |  | 15,000 |  | 3L |  |
| 323 | 1.2.4.7 | **BE/ICS** |  | 10d | 2022-09-12 | 2022-09-23 |  |  |  | 2015-06-01 | 2015-06-26 | 0d | 20d |  |  |  | 16h |  |  |  | 3L |  |
| 324 | 1.2.4.7.1 | New access control |  | 2w | 2022-09-12 | 2022-09-23 | 311 |  |  | 2015-06-01 | 2015-06-26 | 0d | 20d | 0d | start no earlier than 2015-09-21 | Nino Rama [20%] | 16h |  |  |  | 3L |  |
| 325 | 1.2.5 | **ISR 3 (storage area) RIGHT SIDE** |  | 2002d | 2015-01-05 A | 2022-11-11 |  | 7% | 1871.5d | 2015-03-23 | 2016-07-19 | 0d | 5d |  |  |  | 674.4h | 40h | 532,300 | 35,300 | 3R |  |
| 326 | 1.2.5.1 | ISR3 R Availability | milestone | 1d | 2022-01-10 | 2022-01-10 |  |  |  | 2015-06-29 | 2015-06-29 | 0d | 199d | 0d | start no earlier than 2022-01-10 |  |  |  |  |  | 3R |  |
| 327 | 1.2.5.2 | **Civil engineering** |  | 1892d | 2015-01-05 A | 2022-06-10 |  | 2% | 1855.79d | 2015-06-30 | 2015-11-10 | 0d | 115d |  |  |  | 274.4h | 8h | 244,300 | 1,300 | 3R |  |
| 328 | 1.2.5.2.1 | Floor repair (metal rails) |  | 1w | 2022-01-11 | 2022-01-17 | 326 |  |  | 2015-08-03 | 2015-08-07 | 0d | 199d | 0d | start no earlier than 2018-06-01 | Aurelien Benjamin Dodard [35%] | 20h |  | 5,000 |  | 3R | Dimensione |
| 329 | 1.2.5.2.2 | Drainages and holes sealing |  | 4w | 2022-01-18 | 2022-02-14 | 328 |  |  | 2015-08-03 | 2015-08-07 | 0d | 199d |  |  | Aurelien Benjamin Dodard [35%] | 56h |  | 30,000 |  | 3R | Dimensione |
| 330 | 1.2.5.2.3 | Floor waterproofing |  | 4w | 2022-05-16 | 2022-06-10 | 341 |  |  | 2015-07-13 | 2015-07-31 | 0d | 115d |  | start no earlier than 2018-07-02 | Aurelien Benjamin Dodard [35%] | 50.4h |  | 160,000 |  | 3R |  |
| 331 | 1.2.5.2.4 | Hole in corbel for IT |  | 2d | 2015-04-07 A | 2015-04-08 A |  | 100% |  |  |  |  |  |  | start no earlier than 2015-04-07 | Aurelien Benjamin Dodard [35%] | 8h | 8h | 1,300 | 1,300 | 3R |  |
| 332 | 1.2.5.2.5 | Floor repairs |  | 2w | 2015-01-05 | 2015-01-16 |  |  |  | 2015-10-14 | 2015-10-20 | 0d | 1997d |  |  | Aurelien Benjamin Dodard [35%] | 28h |  | 15,000 |  | 3R |  |
| 333 | 1.2.5.2.6 | New stack for evaporators |  | 6w | 2016-09-19 | 2016-10-28 |  |  |  | 2015-06-30 | 2015-08-10 | 0d | 1554d |  | start no earlier than 2016-09-19 | Aurelien Benjamin Dodard [35%] | 84h |  |  |  | 3R |  |
| 334 | 1.2.5.2.7 | Painting 1st phase |  | 1w | 2022-03-07 | 2022-03-11 | 338 |  |  | 2015-09-07 | 2015-09-29 | 0d | 180d |  |  | Aurelien Benjamin Dodard [35%] | 14h |  | 28,000 |  | 3R | Prezioso |
| 335 | 1.2.5.2.8 | Painting 2 nd phase |  | 1w | 2022-05-16 | 2022-05-20 | 341 |  |  | 2015-09-07 | 2015-09-29 | 0d | 130d |  |  | Aurelien Benjamin Dodard [35%] | 14h |  |  |  | 3R | Prezioso |
| 336 | 1.2.5.2.9 | Corbels repair |  | 1.5w | 2018-06-06 | 2018-06-15 | 247 |  |  |  |  |  | 1148d | 0d |  |  |  |  | 5,000 |  | 3R | Dimensione |

| ID | WBS | Task | Duration | Start | Finish | Predecessors | Complete | Remaining | Baseline start | Baseline finish | Baseline duration | Total slack | Free slack | Constraint | Resources | Work | Actual work | Cost | Actual cost | Building | Contractor |
| --- | --- | --- | --- | --- | --- | --- | --- | --- | --- | --- | --- | --- | --- | --- | --- | --- | --- | --- | --- | --- | --- |
| 337 | 1.2.5.3 | **Elec** | 65d | 2022-02-14 | 2022-05-13 |  |  |  | 2016-02-24 | 2016-03-22 | 0d | 115d |  |  |  | 12h |  | 70,000 |  | 3R |  |
| 338 | 1.2.5.3.1 | Removals | 3w | 2022-02-14 | 2022-03-04 |  |  |  |  |  |  | 115d | 0d | start no earlier than 2022-02-14 |  |  |  | 10,000 |  | 3R |  |
| 339 | 1.2.5.3.2 | Installations | 7w | 2022-03-14 | 2022-04-29 | 338FS+1w |  |  |  |  |  | 115d | 0d |  |  |  |  | 60,000 |  | 3R |  |
| 340 | 1.2.5.3.3 | Decommission of CANALIS in the tunnel & other dismantling | 1w | 2022-05-02 | 2022-05-06 | 339 |  |  | 2016-06-08 | 2016-06-14 | 0d | 115d | 0d |  | Miriam Munoz Codoceo [30%] | 12h |  |  |  | 3R |  |
| 341 | 1.2.5.3.4 | Acceptance and inspection | 1w | 2022-05-09 | 2022-05-13 | 340 |  |  |  |  |  | 115d | 0d |  |  |  |  |  |  | 3R |  |
| 342 | 1.2.5.4 | **HVAC** | 1684d | 2015-07-03 A | 2022-02-14 |  | 16% | 1407.93d | 2015-04-13 | 2016-07-19 | 0d | 199d |  |  |  | 332h | 32h | 188,000 | 34,000 | 3R |  |
| 343 | 1.2.5.4.1 | Asbestos diag (campagne) | 2w | 2015-07-03 | 2015-07-16 |  |  |  | 2015-04-13 | 2015-05-27 | 0d | 1873d |  | start no earlier than 2015-07-03 | HSE/SEE | 80h |  |  |  | 3R |  |
| 344 | 1.2.5.4.2 | Ventil units dismantling V3 | 4w | 2016-04-20 A | 2016-05-20 A | 584 | 100% |  | 2015-07-16 | 2015-07-22 | 0d |  |  |  | Aurelien Benjamin Dodard [20%] | 32h | 32h | 34,000 | 34,000 | 3R | Altead, Ram Power |
| 345 | 1.2.5.4.3 | Ducts dismantling | 1w | 2022-02-07 | 2022-02-14 | 338SF |  |  | 2015-06-04 | 2015-06-10 | 0d | 199d | 0d |  | Franck Audinet [30%] | 12h |  | 3,000 |  | 3R | Dalkia |
| 346 | 1.2.5.4.4 | Old gas pipe dismounting | 1d | 2022-02-14 | 2022-02-14 | 345 |  |  |  |  |  | 199d |  |  | Aurelien Benjamin Dodard [20%] | 1.6h |  | 1,000 |  | 3R |  |
| 347 | 1.2.5.4.5 | Underground galleries works (dry raiser) | 5w | 2019-08-15 | 2019-09-19 | 494 |  |  | 2016-04-29 | 2016-05-09 | 1w | 773.5d | 0d |  | Franck Audinet [30%] | 60h |  | 25,000 |  | 3R | IT |
| 348 | 1.2.5.4.6 | Tunnel works (fans, grids etc. including dry riser) | 3w | 2019-09-05 | 2019-09-26 | 349SS |  |  | 2016-05-10 | 2016-05-17 | 0d | 773.5d | 0d |  | Franck Audinet [30%] | 36h |  |  |  | 3R | IT |
| 349 | 1.2.5.4.7 | Ventilation room (over the tunnel) works | 2w | 2019-09-05 | 2019-09-19 | 347SS+3w |  |  | 2016-05-18 | 2016-05-24 | 0d | 773.5d | 0d |  | Franck Audinet [30%] | 24h |  | 125,000 |  | 3R | IT |
| 350 | 1.2.5.4.8 | Works outside (surface - above ventil room) | 4w | 2019-08-15 | 2019-09-12 | 347SS |  |  | 2016-05-18 | 2016-05-24 | 0d | 828.5d | 0d |  | Franck Audinet [30%] | 48h |  |  |  | 3R | IT |
| 351 | 1.2.5.4.9 | Partial acceptance and inspection SR3 only | 3d | 2019-09-12 | 2019-09-17 | 350 |  |  | 2016-06-08 | 2016-06-14 | 0d | 828.5d |  |  | Franck Audinet [30%] | 7.2h |  |  |  | 3R |  |
| 352 | 1.2.5.4.10 | Partial acceptance and inspection ISR3 only | 3d | 2019-10-17 | 2019-10-22 | 315 |  |  |  |  |  | 773.5d | 0d |  | Franck Audinet [30%] | 7.2h |  |  |  | 3R |  |
| 353 | 1.2.5.4.11 | Partial acceptance and inspection ISR3 + ISR4 | 2w | 2019-10-22 | 2019-11-05 | 352 |  |  |  |  |  | 773.5d | 0d |  | Franck Audinet [30%] | 24h |  |  |  | 3R |  |
| 354 | 1.2.5.5 | **Fire detec.** | 10d | 2022-09-19 | 2022-09-30 |  |  |  | 2016-03-16 | 2016-03-31 | 0d | 30d |  |  |  | 16h |  | 20,000 |  | 3R |  |
| 355 | 1.2.5.5.1 | Old system dismantling & new system | 1w | 2022-09-19 | 2022-09-23 | 317 |  |  | 2016-03-16 | 2016-03-22 | 0d | 30d | 0d |  | Denis Raffourt [20%] | 8h |  |  |  | 3R |  |
| 356 | 1.2.5.5.2 | New system commissioning | 1w | 2022-09-26 | 2022-09-30 | 355 |  |  | 2016-03-23 | 2016-03-31 | 0d | 35d |  |  | Denis Raffourt [20%] | 8h |  | 20,000 |  | 3R |  |
| 357 | 1.2.5.6 | **EN/HE** | 40d | 2022-09-19 | 2022-11-11 |  |  |  | 2015-11-11 | 2015-11-24 | 0d | 5d |  |  |  | 24h |  | 10,000 |  | 3R |  |
| 358 | 1.2.5.6.1 | Survey | 1w | 2022-09-19 | 2022-09-23 | 320, 273 |  |  |  |  |  | 40d |  |  |  |  |  |  |  | 3R |  |
| 359 | 1.2.5.6.2 | Rails realignement | 3w | 2022-10-10 | 2022-10-28 | 321, 274 |  |  | 2015-11-11 | 2015-11-24 | 0d | 5d | 0d |  | Helder Lourenco [20%] | 24h |  | 10,000 |  | 3R |  |
| 360 | 1.2.5.6.3 | Electrical feeding line | 2w | 2022-10-31 | 2022-11-11 | 359 |  |  |  |  |  | 5d |  | start no earlier than 2016-08-01 |  |  |  |  |  | 3R |  |

| ID | WBS | Task | Type | Duration | Start | Finish | Predecessors | Complete | Remaining | Baseline start | Baseline finish | Baseline duration | Total slack | Free slack | Constraint | Resources | Work | Actual work | Cost | Actual cost | Building | Contractor |
| --- | --- | --- | --- | --- | --- | --- | --- | --- | --- | --- | --- | --- | --- | --- | --- | --- | --- | --- | --- | --- | --- | --- |
| 361 | 1.2.5.7 | **BE/ICS** |  | 10d | 2022-09-26 | 2022-10-07 |  |  |  | 2015-06-29 | 2015-07-24 | 0d | 20d |  |  |  | 16h |  |  |  | 3R |  |
| 362 | 1.2.5.7.1 | New access control |  | 2w | 2022-09-26 | 2022-10-07 | 324 |  |  | 2015-06-29 | 2015-07-24 | 0d | 20d | 0d |  | Nino Rama [20%] | 16h |  |  |  | 3R |  |
| 363 | 1.2.6 | **T3 parallel gallery** |  | 1410d | 2017-05-10 A | 2022-10-21 |  | 13% | 1228.06d | 2015-06-29 | 2016-07-12 | 0d | 20d |  |  |  | 191.6h | 33.6h | 62,500 | 60,000 | 3PG |  |
| 364 | 1.2.6.1 | T3 Availability | milestone | 1d | 2022-01-10 | 2022-01-10 | 326SS |  |  |  |  |  | 224d |  |  |  |  |  |  |  | 3PG |  |
| 365 | 1.2.6.2 | **Civil engineering** |  | 618.5d | 2017-05-10 A | 2019-10-10 |  | 71% | 181.91d |  |  |  | 811.5d |  |  |  | 47.6h | 33.6h | 62,500 | 60,000 | 3PG |  |
| 366 | 1.2.6.2.1 | Waterproofing underground galleries |  | 12d | 2017-05-10 A | 2017-05-26 A | 603 | 100% |  |  |  |  |  |  |  | Aurelien Benjamin Dodard [35%] | 33.6h | 33.6h | 60,000 | 60,000 | 3PG |  |
| 367 | 1.2.6.2.2 | Filling holes between gallerie and tunnel |  | 1w | 2019-10-03 | 2019-10-10 | 372 |  |  |  |  |  | 811.5d |  |  | Aurelien Benjamin Dodard [35%] | 14h |  | 2,500 |  | 3PG |  |
| 368 | 1.2.6.3 | **Elec** |  | 10d | 2022-09-12 | 2022-09-23 |  |  |  |  |  |  | 40d |  |  |  | 12h |  |  |  | 3PG |  |
| 369 | 1.2.6.3.1 | Installation of new cable trays |  | 1w | 2022-09-12 | 2022-09-16 | 311 |  |  |  |  |  | 40d | 0d | start no earlier than 2016-11-28 |  |  |  |  |  | 3PG |  |
| 370 | 1.2.6.3.2 | Cabling & lighting |  | 1w | 2022-09-19 | 2022-09-23 | 369 |  |  |  |  |  | 40d |  |  | Miriam Munoz Codoceo [30%] | 12h |  |  |  | 3PG |  |
| 371 | 1.2.6.4 | **HVAC** |  | 35d | 2019-08-15 | 2019-10-03 |  |  |  | 2016-06-29 | 2016-07-12 | 0d | 816.5d |  |  |  | 108h |  |  |  | 3PG |  |
| 372 | 1.2.6.4.1 | Gallery works (ducts, grids etc.) - complement |  | 4w | 2019-09-05 | 2019-10-03 | 348SS |  |  |  |  |  | 811.5d | 0d |  | Franck Audinet [30%] | 48h |  |  |  | 3PG |  |
| 373 | 1.2.6.4.2 | Works outside (surface) - complement |  | 5w | 2019-08-15 | 2019-09-19 | 347SS |  |  |  |  |  | 826.5d |  |  | Franck Audinet [30%] | 60h |  |  |  | 3PG |  |
| 374 | 1.2.6.5 | **Fire detec.** |  | 10d | 2022-09-26 | 2022-10-07 |  |  |  | 2016-04-01 | 2016-04-07 | 0d | 30d |  |  |  | 8h |  |  |  | 3PG |  |
| 375 | 1.2.6.5.1 | Old system dismantling & new system |  | 1w | 2022-09-26 | 2022-09-30 | 355 |  |  |  |  |  | 30d | 0d |  |  |  |  |  |  | 3PG |  |
| 376 | 1.2.6.5.2 | New system commissioning |  | 1w | 2022-10-03 | 2022-10-07 | 375 |  |  |  |  |  | 30d |  |  | Denis Raffourt [20%] | 8h |  |  |  | 3PG |  |
| 377 | 1.2.6.6 | **BE/ICS** |  | 10d | 2022-10-10 | 2022-10-21 |  |  |  | 2015-06-29 | 2015-07-24 | 0d | 20d |  |  |  | 16h |  |  |  | 3PG |  |
| 378 | 1.2.6.6.1 | New access control |  | 2w | 2022-10-10 | 2022-10-21 | 362 |  |  |  |  |  | 20d |  |  | Nino Rama [20%] | 16h |  |  |  | 3PG |  |
| 380 | 1.2.7 | **ISR 5 (storage area) LEFT SIDE** |  | 1023d | 2015-01-05 A | 2019-02-11 |  | 64% | 368.12d | 2015-04-13 | 2016-08-30 | 0d | 984d |  |  |  | 593.2h | 299.9h | 962,500 | 526,500 | 5L |  |
| 381 | 1.2.7.1 | ISR 5 L Availability | milestone | 1d | 2016-06-06 | 2016-06-06 |  |  |  | 2015-06-22 | 2015-06-22 | 0d | 1657d | 0d | start no earlier than 2016-06-06 |  |  |  |  |  | 5L |  |
| 382 | 1.2.7.2 | **Civil engineering** |  | 748d | 2015-09-29 A | 2018-10-08 |  | 28% | 541.32d | 2015-11-11 | 2016-03-08 | 0d | 1074d |  |  |  | 160h | 51.1h | 330,500 | 64,500 | 5L |  |
| 383 | 1.2.7.2.1 | Floor repair (metal rails) |  | 1w | 2018-03-26 | 2018-03-30 | 384 |  |  | 2015-08-03 | 2015-08-07 | 0d | 1210d |  | start no earlier than 2018-03-12 | Aurelien Benjamin Dodard [35%] | 20h |  | 5,000 |  | 5L | Dimensione |
| 384 | 1.2.7.2.2 | Drainages and holes sealing |  | 2w | 2018-03-12 | 2018-03-23 |  |  |  | 2015-08-03 | 2015-08-07 | 0d | 1200d | 0d | start no earlier than 2018-03-12 | Aurelien Benjamin Dodard [35%] | 28h |  | 50,000 |  | 5L | Dimensione |
| 385 | 1.2.7.2.3 | Floor waterproofing |  | 4w | 2018-07-02 | 2018-07-27 |  |  |  | 2015-07-13 | 2015-07-31 | 0d | 1105d | 0d | start no earlier than 2018-07-02 | Aurelien Benjamin Dodard [35%] | 50.4h |  | 160,000 |  | 5L |  |
| 386 | 1.2.7.2.4 | Painting 1st phase |  | 1w | 2016-10-26 A | 2016-11-01 A | 453 | 100% |  | 2015-09-07 | 2015-09-29 | 0d |  |  |  | Aurelien Benjamin Dodard [35%] | 14h | 14h | 28,000 | 28,000 | 5L | Prezioso |
| 387 | 1.2.7.2.5 | Painting 2 nd phase |  | 1w | 2017-03-17 A | 2017-03-24 A | 399 | 100% |  | 2015-09-07 | 2015-09-29 | 0d |  |  |  | Aurelien Benjamin Dodard [35%] | 14h | 14h |  |  | 5L | Prezioso |
| 388 | 1.2.7.2.6 | Corbels painting |  | 3w | 2017-09-11 | 2017-09-29 |  |  |  |  |  |  | 1330d |  | start no earlier than 2017-09-11 |  |  |  | 15,000 |  | 5L |  |
| 389 | 1.2.7.2.7 | New door for ventil incl. fire boxes |  | 3d | 2017-04-06 A | 2017-04-10 | 575 | 75% | 0.75d |  |  |  | 2.5d | 0d |  | Aurelien Benjamin Dodard [35%] | 8.4h | 6.3h | 36,000 | 27,000 | 5L | Poralu |
| 390 | 1.2.7.2.8 | Grid and gutter repair (including drying) |  | 3d | 2015-09-29 A | 2015-10-01 A | 245 | 100% |  |  |  |  |  |  |  | Aurelien Benjamin Dodard [35%] | 8.4h | 8.4h | 4,500 | 4,500 | 5L | Scrasa |
| 391 | 1.2.7.2.9 | Temporary plate-forme on the bunker construction |  | 3d | 2016-05-17 | 2016-05-19 |  |  |  |  |  |  | 1669d |  | start no earlier than 2016-05-16 | Aurelien Benjamin Dodard [35%] | 8.4h |  | 12,000 |  | 5L | Ouvaroff |
| 392 | 1.2.7.2.10 | Temporary plate-forme on the bunker dismantling |  | 3d | 2016-07-04 A | 2016-07-06 A | 393 | 100% |  |  |  |  |  |  |  | Aurelien Benjamin Dodard [35%] | 8.4h | 8.4h |  |  | 5L | Ouvaroff |
| 393 | 1.2.7.2.11 | Corbels repair (ext wall) |  | 1w | 2016-06-27 A | 2016-07-01 A | 420 | 100% |  |  |  |  |  |  |  |  |  |  | 5,000 | 5,000 | 5L | Dimensione |
| 394 | 1.2.7.2.12 | Corbels repair (int wall) |  | 3d | 2016-08-03 A | 2016-08-08 A | 524 | 100% |  |  |  |  |  |  |  |  |  |  |  |  | 5L |  |
| 395 | 1.2.7.2.13 | Civil eng works for HVAC |  | 3w | 2018-09-18 | 2018-10-08 | 308 |  |  |  |  |  | 1044d | 0d |  |  |  |  | 15,000 |  | 5L |  |

| ID | WBS | Task | Duration | Start | Finish | Predecessors | Complete | Remaining | Baseline start | Baseline finish | Baseline duration | Total slack | Free slack | Constraint | Resources | Work | Actual work | Cost | Actual cost | Building | Contractor |
| --- | --- | --- | --- | --- | --- | --- | --- | --- | --- | --- | --- | --- | --- | --- | --- | --- | --- | --- | --- | --- | --- |
| 396 | 1.2.7.3 | **Elec** | 90d | 2016-10-28 A | 2017-03-17 A |  | 100% |  | 2016-03-23 | 2016-05-09 | 0d |  |  |  |  |  |  | 80,000 | 80,000 | 5L |  |
| 397 | 1.2.7.3.1 | Removals | 1w | 2016-10-28 A | 2016-11-04 A | 453 | 100% |  |  |  |  |  |  |  |  |  |  | 10,000 | 10,000 | 5L |  |
| 398 | 1.2.7.3.2 | Installations | 9w | 2016-12-16 A | 2017-03-03 A | 454 | 100% |  |  |  |  |  |  |  |  |  |  | 70,000 | 70,000 | 5L |  |
| 399 | 1.2.7.3.3 | Decommission of CANALIS in the tunnel & other dismantling | 2w | 2017-03-03 A | 2017-03-17 A | 398 | 100% |  |  |  |  |  |  |  |  |  |  |  |  | 5L |  |
| 400 | 1.2.7.4 | **HVAC** | 1023d | 2015-01-05 A | 2019-02-11 |  | 62% | 388.8d | 2015-04-13 | 2016-08-30 | 0d | 984d |  |  |  | 329.2h | 160.8h | 270,000 | 119,000 | 5L |  |
| 401 | 1.2.7.4.1 | Ventil units dismantling V4 | 12d | 2016-05-23 A | 2016-06-07 A | 344 | 100% |  | 2015-07-02 | 2015-07-08 | 0d |  |  |  | Aurelien Benjamin Dodard [40%] | 38.4h | 38.4h | 68,000 | 68,000 | 5L | Altead, Ram Power |
| 402 | 1.2.7.4.2 | Asbestos diag (campagne) | 2w | 2015-06-19 A | 2015-07-02 A |  | 100% |  | 2015-04-13 | 2015-05-27 | 0d |  |  | start no earlier than 2015-06-19 | DGS/SEE | 80h | 80h |  |  | 5L |  |
| 403 | 1.2.7.4.3 | Ventil units dismantling V5 | 12d | 2016-06-24 A | 2016-07-11 A | 258 | 100% |  | 2015-07-30 | 2015-08-05 | 0d |  |  |  | Aurelien Benjamin Dodard [20%] | 19.2h | 19.2h | 34,000 | 34,000 | 5L | Altead, Ram Power |
| 404 | 1.2.7.4.4 | Ducts dismantling V5 | 3d | 2015-01-05 A | 2015-01-07 A |  | 100% |  | 2015-06-11 | 2015-06-17 | 0d |  |  |  | Franck Audinet [30%] | 7.2h | 7.2h | 17,000 | 17,000 | 5L | Dalkia |
| 405 | 1.2.7.4.5 | Ducts dismantling tunnel (ext wall) | 14.6w | 2016-10-10 A | 2017-02-01 A |  | 100% |  |  |  |  |  |  | start no earlier than 2016-10-10 | Franck Audinet [10%] | 4h | 4h |  |  | 5L |  |
| 406 | 1.2.7.4.6 | Ducts dismantling tunnel (int wall) | 1w | 2016-10-17 A | 2016-10-21 A |  | 100% |  |  |  |  |  |  |  | Franck Audinet [30%] | 12h | 12h |  |  | 5L |  |
| 407 | 1.2.7.4.7 | Old gas pipe dismounting | 1d | 2016-06-20 | 2016-06-20 |  |  |  |  |  |  | 1647d |  | start no earlier than 2016-06-20 | Aurelien Benjamin Dodard [20%] | 1.6h |  | 1,000 |  | 5L |  |
| 408 | 1.2.7.4.8 | Underground galleries works (dry raiser) | 5w | 2018-12-14 | 2019-01-17 | 267 |  |  | 2016-04-29 | 2016-05-09 | 1w | 773.5d | 0d |  | Franck Audinet [30%] | 60h |  | 25,000 |  | 5L | IT |
| 409 | 1.2.7.4.9 | Tunnel works (fans, grids etc. including dry riser) | 2.5w | 2019-01-04 | 2019-01-22 | 410SS |  |  | 2016-05-10 | 2016-05-17 | 0d | 773.5d | 0d |  | Franck Audinet [30%] | 30h |  |  |  | 5L | IT |
| 410 | 1.2.7.4.10 | Ventilation room (over the tunnel) works | 2w | 2019-01-04 | 2019-01-17 | 408SS+3w |  |  | 2016-05-18 | 2016-05-24 | 0d | 773.5d | 0d |  | Franck Audinet [30%] | 24h |  | 125,000 |  | 5L | IT |
| 411 | 1.2.7.4.11 | Works outside (surface - above ventil room) | 4w | 2018-12-14 | 2019-01-10 | 408SS |  |  | 2016-05-18 | 2016-05-24 | 0d | 1006d |  |  | Franck Audinet [30%] | 48h |  |  |  | 5L | IT |
| 412 | 1.2.7.4.12 | Partial acceptance and inspection ISR5 only | 2d | 2019-02-08 | 2019-02-11 | 459 |  |  | 2016-08-24 | 2016-08-30 | 0d | 773.5d | 0d |  | Franck Audinet [30%] | 4.8h |  |  |  | 5L |  |
| 413 | 1.2.7.5 | **Fire detec.** | 10d | 2017-04-18 A | 2017-05-02 A |  | 100% |  | 2016-04-08 | 2016-04-21 | 0d |  |  |  |  | 16h | 16h | 18,000 | 18,000 | 5L |  |
| 414 | 1.2.7.5.1 | Old system dismantling & new system | 1w | 2017-04-18 A | 2017-04-24 A |  | 100% |  | 2016-04-08 | 2016-04-14 | 0d |  |  | start no earlier than 2017-04-18 | Denis Raffourt [20%] | 8h | 8h |  |  | 5L |  |
| 415 | 1.2.7.5.2 | New system commissioning | 1w | 2017-04-25 A | 2017-05-02 A | 414 | 100% |  | 2016-04-15 | 2016-04-21 | 0d |  |  |  | Denis Raffourt [20%] | 8h | 8h | 18,000 | 18,000 | 5L |  |
| 416 | 1.2.7.6 | **IT/CS** | 18d | 2016-11-07 A | 2016-11-30 |  | 50% | 9d | 2016-07-15 | 2016-07-18 | 0d | 1531d |  |  |  |  |  | 20,000 | 10,000 | 5L |  |
| 417 | 1.2.7.6.1 | New cable and antenna | 3.6w | 2016-11-07 A | 2016-11-30 |  | 50% | 1.8w | 2016-07-15 | 2016-07-18 | 0d | 1531d |  | start no earlier than 2016-11-07 |  |  |  | 20,000 | 10,000 | 5L |  |
| 418 | 1.2.7.7 | **EN/HE** | 216d | 2016-03-17 A | 2017-02-03 |  | 96% | 7.71d | 2016-02-03 | 2016-03-01 | 0d | 1494d |  |  |  | 72h | 72h | 244,000 | 235,000 | 5L |  |
| 419 | 1.2.7.7.1 | Handling operations | 4w | 2016-03-17 A | 2016-04-15 A |  | 100% |  |  |  |  |  |  | finish no earlier than 2016-04-15 | Helder Lourenco [20%] | 32h | 32h |  |  | 5L |  |
| 420 | 1.2.7.7.2 | Rails & corbels partial repair (all walls) | 5w | 2016-05-23 A | 2016-06-24 A |  | 100% |  | 2016-02-03 | 2016-03-01 | 0d |  |  | start no earlier than 2016-05-23 | Helder Lourenco [20%] | 40h | 40h | 208,000 | 208,000 | 5L |  |
| 421 | 1.2.7.7.3 | Electrical feeding line | 2w | 2016-07-04 A | 2016-07-15 | 420FS+1w | 75% | 0.5w |  |  |  | 1628d |  |  |  |  |  | 36,000 | 27,000 | 5L |  |
| 422 | 1.2.7.7.4 | Bunker demolition and material removal | 3w | 2017-01-16 A | 2017-02-03 A | 540 | 100% |  |  |  |  |  |  | start no earlier than 2016-12-05 |  |  |  |  |  | 5L |  |

| ID | WBS | Task | Type | Duration | Start | Finish | Predecessors | Complete | Remaining | Baseline start | Baseline finish | Baseline duration | Total slack | Free slack | Constraint | Resources | Work | Actual work | Cost | Actual cost | Building | Contractor |
| --- | --- | --- | --- | --- | --- | --- | --- | --- | --- | --- | --- | --- | --- | --- | --- | --- | --- | --- | --- | --- | --- | --- |
| 423 | 1.2.7.8 | **BE/ICS** |  | 10d | 2018-06-04 | 2018-06-15 |  |  |  | 2015-07-27 | 2015-08-21 | 0d | 1075d |  |  |  | 16h |  |  |  | 5L |  |
| 424 | 1.2.7.8.1 | New access control |  | 2w | 2018-06-04 | 2018-06-15 |  |  |  | 2015-07-27 | 2015-08-21 | 0d | 1075d | 0d | start no earlier than 2018-06-04 | Nino Rama [20%] | 16h |  |  |  | 5L |  |
| 425 | 1.2.8 | **T5 parallel gallery** |  | 672d | 2016-06-06 A | 2019-02-07 |  | 24% | 509.42d | 2015-06-22 | 2016-08-23 | 0d | 986d |  |  |  | 183.6h | 33.6h | 65,000 | 60,000 | 5PG |  |
| 426 | 1.2.8.1 | T5 Availability | milestone | 1d | 2016-06-06 | 2016-06-06 | 381SS |  |  | 2015-06-22 | 2015-06-22 | 0d | 1657d |  |  |  |  |  |  |  | 5PG |  |
| 427 | 1.2.8.2 | **Civil engineering** |  | 483d | 2017-03-13 A | 2019-02-07 |  | 71% | 142.06d |  |  |  | 986d |  |  |  | 47.6h | 33.6h | 65,000 | 60,000 | 5PG |  |
| 428 | 1.2.8.2.1 | Waterproofing underground galleries |  | 12d | 2017-03-13 A | 2017-03-28 A |  | 100% |  | 2015-11-11 | 2015-11-24 | 0d |  |  | start no earlier than 2017-03-13 | Aurelien Benjamin Dodard [35%] | 33.6h | 33.6h | 60,000 | 60,000 | 5PG |  |
| 429 | 1.2.8.2.2 | Filling holes between gallerie and tunnel |  | 1w | 2019-02-01 | 2019-02-07 | 434 |  |  |  |  |  | 986d |  |  | Aurelien Benjamin Dodard [35%] | 14h |  | 5,000 |  | 5PG |  |
| 430 | 1.2.8.3 | **Elec** |  | 25d | 2016-11-28 A | 2017-01-13 |  | 5% | 23.75d |  |  |  | 1509d |  |  |  | 12h |  |  |  | 5PG |  |
| 431 | 1.2.8.3.1 | Installation of new cable trays |  | 1w | 2016-11-28 A | 2016-12-02 |  | 10% | 0.9w |  |  |  | 1509d | 0d | start no earlier than 2016-11-28 |  |  |  |  |  | 5PG |  |
| 432 | 1.2.8.3.2 | Cabling & lighting |  | 1w | 2017-01-09 | 2017-01-13 | 431FS+3w |  |  |  |  |  | 1509d |  |  | Miriam Munoz Codoceo [30%] | 12h |  |  |  | 5PG |  |
| 433 | 1.2.8.4 | **HVAC** |  | 35d | 2018-12-14 | 2019-01-31 |  |  |  | 2016-08-10 | 2016-08-23 | 0d | 991d |  |  |  | 108h |  |  |  | 5PG |  |
| 434 | 1.2.8.4.1 | Gallery works (ducts, grids etc.) - complement |  | 4w | 2019-01-04 | 2019-01-31 | 409SS |  |  | 2016-05-10 | 2016-05-17 | 0d | 986d | 0d |  | Franck Audinet [30%] | 48h |  |  |  | 5PG | IT |
| 435 | 1.2.8.4.2 | Works outside (surface) - complement |  | 5w | 2018-12-14 | 2019-01-17 | 408SS |  |  | 2016-05-18 | 2016-05-24 | 0d | 1001d |  |  | Franck Audinet [30%] | 60h |  |  |  | 5PG | IT |
| 436 | 1.2.8.5 | **Fire detec.** |  | 10d | 2017-04-18 A | 2017-05-02 A |  | 100% |  | 2016-04-22 | 2016-04-28 | 0d |  |  |  |  |  |  |  |  | 5PG |  |
| 437 | 1.2.8.5.1 | Old system dismantling & new system |  | 1w | 2017-04-18 A | 2017-04-24 A | 414SS | 100% |  |  |  |  |  |  |  |  |  |  |  |  | 5PG |  |
| 438 | 1.2.8.5.2 | New system commissioning |  | 1w | 2017-04-25 A | 2017-05-02 A | 437 | 100% |  | 2016-04-22 | 2016-04-28 | 0d |  |  |  |  |  |  |  |  | 5PG |  |
| 439 | 1.2.8.6 | **BE/ICS** |  | 10d | 2018-06-18 | 2018-06-29 | 424 |  |  | 2015-07-27 | 2015-08-21 | 0d | 1075d |  |  |  | 16h |  |  |  | 5L |  |
| 440 | 1.2.8.6.1 | New access control |  | 2w | 2018-06-18 | 2018-06-29 |  |  |  | 2015-07-27 | 2015-08-21 | 0d | 1075d | 0d | start no earlier than 2018-06-04 | Nino Rama [20%] | 16h |  |  |  | 5L |  |
| 441 | 1.2.9 | **ISR 5 (storage area) RIGHT SIDE** |  | 777d | 2016-01-04 A | 2019-02-07 |  | 69% | 240.07d | 2015-04-13 | 2016-08-30 | 0d | 986d |  |  |  | 245.2h | 99.2h | 508,000 | 167,000 | 5R |  |
| 442 | 1.2.9.1 | ISR5 R Availability | milestone | 1d | 2016-01-04 | 2016-01-04 |  |  |  | 2015-06-22 | 2015-06-22 | 0d | 1762d |  | start no earlier than 2016-01-04 |  |  |  |  |  | 5R |  |
| 443 | 1.2.9.2 | **Civil engineering** |  | 533d | 2016-07-04 A | 2018-08-24 |  | 33% | 355.33d | 2015-11-11 | 2016-03-08 | 0d | 1105d |  |  |  | 126.4h | 28h | 248,000 | 33,000 | 5R |  |
| 444 | 1.2.9.2.1 | Floor repair (metal rails) |  | 1w | 2018-04-09 | 2018-04-13 | 445 |  |  | 2015-08-03 | 2015-08-07 | 0d | 1200d |  | start no earlier than 2018-03-12 | Aurelien Benjamin Dodard [35%] | 20h |  | 5,000 |  | 5R | Dimensione |
| 445 | 1.2.9.2.2 | Drainages and holes sealing |  | 2w | 2018-03-26 | 2018-04-06 | 384 |  |  | 2015-08-03 | 2015-08-07 | 0d | 1200d | 0d | start no earlier than 2018-03-12 | Aurelien Benjamin Dodard [35%] | 28h |  | 50,000 |  | 5R | Dimensione |
| 446 | 1.2.9.2.3 | Floor waterproofing |  | 4w | 2018-07-30 | 2018-08-24 | 385 |  |  | 2015-07-13 | 2015-07-31 | 0d | 1105d |  | start no earlier than 2018-07-02 | Aurelien Benjamin Dodard [35%] | 50.4h |  | 160,000 |  | 5R |  |
| 447 | 1.2.9.2.4 | Painting 1st phase |  | 1w | 2016-10-28 A | 2016-11-04 A | 386SS | 100% |  | 2015-09-07 | 2015-09-29 | 0d |  |  |  | Aurelien Benjamin Dodard [35%] | 14h | 14h | 28,000 | 28,000 | 5R | Prezioso |
| 448 | 1.2.9.2.5 | Painting 2nd phase |  | 1w | 2017-04-05 A | 2017-04-12 A | 455FS+4w | 100% |  | 2015-09-07 | 2015-09-29 | 0d |  |  |  | Aurelien Benjamin Dodard [35%] | 14h | 14h |  |  | 5R | Prezioso |
| 449 | 1.2.9.2.6 | Corbels repair |  | 1.5w | 2016-07-04 A | 2016-07-13 A | 393 | 100% |  |  |  |  |  |  |  |  |  |  | 5,000 | 5,000 | 5R | Dimensione |

| ID | WBS | Task | Type | Duration | Start | Finish | Predecessors | Complete | Remaining | Baseline start | Baseline finish | Baseline duration | Total slack | Free slack | Constraint | Resources | Work | Actual work | Cost | Actual cost | Building | Contractor |
| --- | --- | --- | --- | --- | --- | --- | --- | --- | --- | --- | --- | --- | --- | --- | --- | --- | --- | --- | --- | --- | --- | --- |
| 450 | 1.2.9.3 | **Elec** |  | 92.5d | 2016-10-17 A | 2017-03-08 |  | 99% | 1.2d | 2016-03-23 | 2016-05-09 | 0d | 15d |  |  |  |  |  | 90,000 | 90,000 | 5R |  |
| 451 | 1.2.9.3.1 | Commandes |  | 2w | 2016-10-17 A | 2016-10-28 A |  | 100% |  |  |  |  |  |  | start no earlier than 2016-08-29 |  |  |  |  |  | 5R |  |
| 452 | 1.2.9.3.2 | Installation drawings |  | 3w | 2016-10-31 A | 2016-11-18 A | 451 | 100% |  |  |  |  |  |  |  |  |  |  |  |  | 5R |  |
| 453 | 1.2.9.3.3 | Removals |  | 1w | 2016-10-19 A | 2016-10-25 A | 485 | 100% |  |  |  |  |  |  |  |  |  |  | 10,000 | 10,000 | 5R |  |
| 454 | 1.2.9.3.4 | Installations |  | 5w | 2016-11-11 A | 2016-12-16 A | 486SS+1w | 100% |  |  |  |  |  |  |  |  |  |  | 80,000 | 80,000 | 5R |  |
| 455 | 1.2.9.3.5 | Decommission of CANALIS in the tunnel & other dismantling |  | 3d | 2017-03-03 A | 2017-03-08 | 399SS | 75% | 0.75d |  |  |  | 15d | 0d |  |  |  |  |  |  | 5R |  |
| 456 | 1.2.9.4 | **HVAC** |  | 573d | 2016-10-24 A | 2019-02-07 |  | 18% | 468.82d | 2015-04-13 | 2016-08-30 | 0d | 986d |  |  |  | 38.8h | 7.2h | 132,000 | 6,000 | 5R |  |
| 457 | 1.2.9.4.1 | Ducts dismantling |  | 3d | 2016-10-24 A | 2016-10-26 A | 406 | 100% |  | 2015-06-11 | 2015-06-17 | 0d |  |  | start no earlier than 2015-04-07 | Franck Audinet [30%] | 7.2h | 7.2h | 6,000 | 6,000 | 5R | Dalkia |
| 458 | 1.2.9.4.2 | Old gas pipe dismounting |  | 1d | 2016-10-27 | 2016-10-27 | 457 |  |  |  |  |  | 1555d |  |  | Aurelien Benjamin Dodard [20%] | 1.6h |  | 1,000 |  | 5R |  |
| 459 | 1.2.9.4.3 | Tunnel works (fans, grids etc. including dry riser) |  | 2.5w | 2019-01-22 | 2019-02-07 | 409 |  |  | 2016-05-10 | 2016-05-17 | 0d | 773.5d | 0d |  | Franck Audinet [30%] | 30h |  | 125,000 |  | 5R | IT |
| 460 | 1.2.9.5 | **Fire detec.** |  | 10d | 2017-04-25 A | 2017-05-09 A |  | 100% |  | 2016-04-08 | 2016-04-21 | 0d |  |  |  |  | 16h | 16h | 18,000 | 18,000 | 5R |  |
| 461 | 1.2.9.5.1 | Old system dismantling & new system |  | 1w | 2017-04-25 A | 2017-05-02 A | 437 | 100% |  | 2016-04-08 | 2016-04-14 | 0d |  |  |  | Denis Raffourt [20%] | 8h | 8h |  |  | 5R |  |
| 462 | 1.2.9.5.2 | New system commissioning |  | 1w | 2017-05-03 A | 2017-05-09 A | 461 | 100% |  | 2016-04-15 | 2016-04-21 | 0d |  |  |  | Denis Raffourt [20%] | 8h | 8h | 18,000 | 18,000 | 5R |  |
| 463 | 1.2.9.6 | **IT/CS** |  | 2d | 2016-11-07 A | 2016-11-08 A |  | 100% |  | 2016-07-15 | 2016-07-18 | 0d |  |  |  |  |  |  | 20,000 | 20,000 | 5R |  |
| 464 | 1.2.9.6.1 | New cable and antenna |  | 2d | 2016-11-07 A | 2016-11-08 A | 417SS | 100% |  | 2016-07-15 | 2016-07-18 | 0d |  |  |  |  |  |  | 20,000 | 20,000 | 5R |  |
| 465 | 1.2.9.7 | **EN/HE** |  | 69d | 2016-05-09 A | 2016-08-12 A |  | 100% |  | 2016-02-03 | 2016-03-01 | 0d |  |  |  |  | 48h | 48h |  |  | 5R |  |
| 466 | 1.2.9.7.1 | Survey |  | 1w | 2016-05-09 A | 2016-05-13 A |  | 100% |  |  |  |  |  |  | start no earlier than 2016-05-09 |  |  |  |  |  | 5R |  |
| 467 | 1.2.9.7.2 | Rails & corbels repair |  | 6w | 2016-05-17 A | 2016-06-27 A | 466 | 100% |  | 2016-02-03 | 2016-03-01 | 0d |  |  |  | Helder Lourenco [20%] | 48h | 48h |  |  | 5R |  |
| 468 | 1.2.9.7.3 | Electrical feeding line |  | 2w | 2016-08-01 A | 2016-08-12 A | 467 | 100% |  |  |  |  |  |  | start no earlier than 2016-08-01 |  |  |  |  |  | 5R |  |
| 469 | 1.2.9.8 | **BE/ICS** |  | 10d | 2018-07-02 | 2018-07-13 |  |  |  | 2015-07-27 | 2015-08-21 | 0d | 1075d |  |  |  | 16h |  |  |  | 5R |  |
| 470 | 1.2.9.8.1 | New access control |  | 2w | 2018-07-02 | 2018-07-13 | 424, 440 |  |  | 2015-07-27 | 2015-08-21 | 0d | 1075d | 0d |  | Nino Rama [20%] | 16h |  |  |  | 5R |  |
| 472 | 1.2.10 | **ISR 6 (storage area) LEFT SIDE - INTERNAL WALL ONLY** |  | 1101.5d | 2015-04-07 A | 2019-08-29 |  | 32% | 754.45d | 2015-06-18 | 2016-06-07 | 0d | 841.5d |  |  |  | 431.8h | 103.2h | 488,000 | 150,000 | 6L |  |
| 473 | 1.2.10.1 | ISR6 L Availability | milestone | 1d | 2015-04-07 | 2015-04-07 |  |  |  | 2015-06-29 | 2015-06-29 | 0d | 1942d | 0d | start no earlier than 2015-04-07 |  |  |  |  |  | 6L |  |
| 474 | 1.2.10.2 | **Civil engineering** |  | 760d | 2015-10-02 A | 2018-10-29 |  | 30% | 532.52d | 2016-02-03 | 2016-05-11 | 0d | 1059d |  |  |  | 164.2h | 61.6h | 236,000 | 48,000 | 6L |  |
| 475 | 1.2.10.2.1 | Floor repair (metal rails) |  | 1w | 2018-04-09 | 2018-04-13 | 476 |  |  | 2015-08-03 | 2015-08-07 | 0d | 1200d |  | start no earlier than 2018-03-12 | Aurelien Benjamin Dodard [35%] | 20h |  | 5,000 |  | 6L | Dimensione |
| 476 | 1.2.10.2.2 | Drainages and holes sealing |  | 2w | 2018-03-26 | 2018-04-06 | 384 |  |  | 2015-08-03 | 2015-08-07 | 0d | 1200d | 0d | start no earlier than 2018-03-12 | Aurelien Benjamin Dodard [35%] | 28h |  | 50,000 |  | 6L | Dimensione |
| 477 | 1.2.10.2.3 | Floor waterproofing |  | 4w | 2018-07-30 | 2018-08-24 | 385 |  |  | 2015-07-13 | 2015-07-31 | 0d | 1105d |  | start no earlier than 2018-07-02 | Aurelien Benjamin Dodard [35%] | 50.4h |  | 100,000 |  | 6L |  |
| 478 | 1.2.10.2.4 | Painting 1st phase |  | 1w | 2016-10-21 A | 2016-10-28 A | 447SF | 100% |  | 2015-09-07 | 2015-09-29 | 0d |  |  |  | Aurelien Benjamin Dodard [35%] | 14h | 14h | 22,000 | 22,000 | 6L | Prezioso |
| 479 | 1.2.10.2.5 | Painting 2nd phase |  | 1w | 2017-04-12 A | 2017-04-21 A | 448 | 100% |  | 2015-09-07 | 2015-09-29 | 0d |  |  |  | Aurelien Benjamin Dodard [35%] | 14h | 14h |  |  | 6L | Prezioso |
| 480 | 1.2.10.2.6 | New door for ventil incl. fire boxes |  | 3d | 2017-03-29 A | 2017-03-31 |  | 50% | 1.5d |  |  |  | 1.5d | 0d | start no earlier than 2017-03-29 | Aurelien Benjamin Dodard [35%] | 8.4h | 4.2h | 36,000 | 18,000 | 6L |  |
| 481 | 1.2.10.2.7 | Grid and gutter repair (including drying) |  | 3d | 2015-10-02 A | 2015-10-06 A | 390 | 100% |  |  |  |  |  |  |  | Aurelien Benjamin Dodard [35%] | 8.4h | 8.4h | 4,500 | 4,500 | 6L | Scrasa |
| 482 | 1.2.10.2.8 | Corbels repair |  | 1.5w | 2016-07-13 A | 2016-07-22 A | 449 | 100% |  | 2016-03-09 | 2016-03-31 | 0d |  |  |  | Aurelien Benjamin Dodard [35%] | 21h | 21h | 3,500 | 3,500 | 6L | Dimensione |
| 483 | 1.2.10.2.9 | Civil eng works for HVAC |  | 3w | 2018-10-09 | 2018-10-29 | 395 |  |  |  |  |  | 1044d | 0d |  |  |  |  | 15,000 |  | 6L |  |

| ID | WBS | Task | Type | Duration | Start | Finish | Predecessors | Complete | Remaining | Baseline start | Baseline finish | Baseline duration | Total slack | Free slack | Constraint | Resources | Work | Actual work | Cost | Actual cost | Building | Contractor |
| --- | --- | --- | --- | --- | --- | --- | --- | --- | --- | --- | --- | --- | --- | --- | --- | --- | --- | --- | --- | --- | --- | --- |
| 484 | 1.2.10.3 | **Elec** |  | 98.5d | 2016-10-12 A | 2017-03-13 A |  | 100% |  | 2016-05-10 | 2016-06-07 | 0d |  |  |  |  |  |  | 68,000 | 68,000 | 6L |  |
| 485 | 1.2.10.3.1 | Removals |  | 1w | 2016-10-12 A | 2016-10-18 A | 530 | 100% |  |  |  |  |  |  | start no earlier than 2016-10-11 |  |  |  | 2,000 | 2,000 | 6L |  |
| 486 | 1.2.10.3.2 | Installations |  | 3.4w | 2016-11-04 A | 2016-11-29 A | 397 | 100% |  |  |  |  |  |  | start no earlier than 2016-10-18 |  |  |  | 66,000 | 66,000 | 6L |  |
| 487 | 1.2.10.3.3 | Decommission of CANALIS in the tunnel & other dismantling |  | 3d | 2017-03-08 A | 2017-03-13 A | 455 | 100% |  |  |  |  |  |  |  |  |  |  |  |  | 6L |  |
| 488 | 1.2.10.4 | **HVAC** |  | 870.5d | 2016-03-15 A | 2019-08-29 |  | 12% | 765.51d | 2015-06-18 | 2016-03-15 | 0d | 841.5d |  |  |  | 243.6h | 33.6h | 184,000 | 34,000 | 6L |  |
| 489 | 1.2.10.4.1 | Ventil units dismantling V6 |  | 12d | 2016-03-15 A | 2016-04-01 A | 27FS+4w | 100% |  | 2015-08-13 | 2015-08-19 | 0d |  |  |  | Aurelien Benjamin Dodard [35%] | 33.6h | 33.6h | 34,000 | 34,000 | 6L | Altead, Ram Power |
| 490 | 1.2.10.4.2 | Underground galleries works (dry raiser) |  | 5w | 2019-06-06 | 2019-07-11 | 591 |  |  | 2016-04-29 | 2016-05-09 | 1w | 773.5d | 0d |  | Franck Audinet [30%] | 60h |  | 25,000 |  | 6L | IT |
| 491 | 1.2.10.4.3 | Tunnel works (fans, grids etc. including dry riser) |  | 2.5w | 2019-06-27 | 2019-07-15 | 492SS |  |  | 2016-05-10 | 2016-05-17 | 0d | 773.5d | 0d |  | Franck Audinet [30%] | 30h |  |  |  | 6L | IT |
| 492 | 1.2.10.4.4 | Ventilation room (over the tunnel) works |  | 2w | 2019-06-27 | 2019-07-11 | 490SS+3w |  |  | 2016-05-18 | 2016-05-24 | 0d | 773.5d | 0d |  | Franck Audinet [30%] | 24h |  | 125,000 |  | 6L | IT |
| 493 | 1.2.10.4.5 | Works outside (surface - above ventil room) |  | 4w | 2019-06-06 | 2019-07-04 | 490SS |  |  | 2016-05-18 | 2016-05-24 | 0d | 881.5d |  |  | Franck Audinet [30%] | 48h |  |  |  | 6L | IT |
| 494 | 1.2.10.4.6 | Partial acceptance and inspection ISR5+ISR6 |  | 2w | 2019-08-01 | 2019-08-15 | 533 |  |  | 2016-06-08 | 2016-06-14 | 0d | 773.5d | 0d |  | Franck Audinet [30%] | 24h |  |  |  | 6L |  |
| 495 | 1.2.10.4.7 | Partial acceptance and inspection ISR6+ISR7 |  | 2w | 2019-08-15 | 2019-08-29 | 494 |  |  | 2016-06-08 | 2016-06-14 | 0d | 841.5d |  |  | Franck Audinet [30%] | 24h |  |  |  | 6L |  |
| 496 | 1.2.10.5 | **Fire detec.** |  | 10d | 2017-04-21 A | 2017-05-08 A |  | 100% |  | 2016-04-29 | 2016-05-09 | 0d |  |  |  |  | 8h | 8h |  |  | 6L |  |
| 497 | 1.2.10.5.1 | Old system dismantling & new system |  | 1w | 2017-04-21 A | 2017-04-28 A | 479 | 100% |  | 2016-04-29 | 2016-05-09 | 0d |  |  |  | Denis Raffourt [20%] | 8h | 8h |  |  | 6L |  |
| 498 | 1.2.10.5.2 | New system commissioning |  | 1w | 2017-04-28 A | 2017-05-08 A | 497 | 100% |  |  |  |  |  |  |  |  |  |  |  |  | 6L |  |
| 499 | 1.2.10.6 | **BE/ICS** |  | 10d | 2018-07-16 | 2018-07-27 |  |  |  | 2015-08-24 | 2015-09-21 | 0d | 1075d | 0d |  |  | 16h |  |  |  | 6L |  |
| 500 | 1.2.10.6.1 | New access control |  | 2w | 2018-07-16 | 2018-07-27 | 470 |  |  | 2015-08-24 | 2015-09-21 | 0d | 1075d | 10d |  | Nino Rama [20%] | 16h |  |  |  | 6L |  |
| 501 | 1.2.11 | **T6 parallel gallery** |  | 1150.5d | 2015-01-05 A | 2019-08-08 |  | 15% | 977.42d | 2015-06-29 | 2016-05-17 | 0d | 856.5d |  |  |  | 213.6h | 33.6h | 100,000 | 60,000 | 6PG |  |
| 502 | 1.2.11.1 | T6 Availability | milestone | 1d | 2015-04-07 | 2015-04-07 | 473SS |  |  | 2015-06-29 | 2015-06-29 | 0d | 1942d |  |  |  |  |  |  |  | 6PG |  |
| 503 | 1.2.11.2 | **Civil engineering** |  | 556.5d | 2017-05-29 A | 2019-08-01 |  | 38% | 347.81d |  |  |  | 861.5d |  |  |  | 61.6h | 33.6h | 90,000 | 60,000 | 6PG |  |
| 504 | 1.2.11.2.1 | Waterproofing underground galleries |  | 12d | 2017-05-29 A | 2017-06-14 A | 366 | 100% |  | 2016-02-03 | 2016-02-16 | 0d |  |  |  | Aurelien Benjamin Dodard [35%] | 33.6h | 33.6h | 60,000 | 60,000 | 6PG |  |
| 505 | 1.2.11.2.2 | Doors for access control |  | 1w | 2018-04-23 | 2018-04-27 | 507 |  |  |  |  |  | 1190d |  |  | Aurelien Benjamin Dodard [35%] | 14h |  |  |  | 6PG |  |
| 506 | 1.2.11.2.3 | Filling holes between gallerie and tunnel |  | 1w | 2019-07-25 | 2019-08-01 | 512 |  |  |  |  |  | 861.5d |  |  | Aurelien Benjamin Dodard [35%] | 14h |  | 5,000 |  | 6PG |  |
| 507 | 1.2.11.2.4 | Fire walls (to be confirmed) |  | 2w | 2018-04-09 | 2018-04-20 | 306 |  |  |  |  |  | 1190d | 0d |  |  |  |  | 25,000 |  | 6PG |  |

| ID | WBS | Task | Type | Duration | Start | Finish | Predecessors | Complete | Remaining | Baseline start | Baseline finish | Baseline duration | Total slack | Free slack | Constraint | Resources | Work | Actual work | Cost | Actual cost | Building | Contractor |
| --- | --- | --- | --- | --- | --- | --- | --- | --- | --- | --- | --- | --- | --- | --- | --- | --- | --- | --- | --- | --- | --- | --- |
| 508 | 1.2.11.3 | **Elec** |  | 5d | 2017-03-15 | 2017-03-22 |  |  |  |  |  |  | 15d |  |  |  | 12h |  |  |  | 6PG |  |
| 509 | 1.2.11.3.1 | Cabling & lighting |  | 1w | 2017-03-15 | 2017-03-22 | 487, 531 |  |  |  |  |  | 15d | 0d |  | Miriam Munoz Codoceo [30%] | 12h |  |  |  | 6PG |  |
| 510 | 1.2.11.4 | **HVAC** |  | 45d | 2019-06-06 | 2019-08-08 |  |  |  | 2016-02-03 | 2016-02-16 | 0d | 856.5d |  |  |  | 124h |  |  |  | 6PG |  |
| 511 | 1.2.11.4.1 | Fire subcompartment installation |  | 2w | 2019-07-25 | 2019-08-08 | 512 |  |  |  |  |  | 856.5d |  |  | Aurelien Benjamin Dodard [20%] | 16h |  |  |  | 6PG |  |
| 512 | 1.2.11.4.2 | Gallery works (ducts, grids etc.) |  | 4w | 2019-06-27 | 2019-07-25 | 491SS |  |  | 2016-05-10 | 2016-05-17 | 0d | 856.5d | 0d |  | Franck Audinet [30%] | 48h |  |  |  | 6PG | IT |
| 513 | 1.2.11.4.3 | Works outside (surface) |  | 5w | 2019-06-06 | 2019-07-11 | 490SS |  |  | 2016-05-18 | 2016-05-24 | 0d | 876.5d |  |  | Franck Audinet [30%] | 60h |  |  |  | 6PG | IT |
| 514 | 1.2.11.5 | **Fire detec.** |  | 550.5d | 2015-01-05 A | 2017-03-29 |  | 50% | 275.25d | 2016-05-10 | 2016-05-17 | 0d | 1456.5d |  |  |  |  |  | 10,000 |  | 6PG |  |
| 515 | 1.2.11.5.1 | Old system dismantling & new system |  | 1w | 2017-03-22 A | 2017-03-29 A | 509 | 100% |  | 2016-05-10 | 2016-05-17 | 0d |  |  |  |  |  |  |  |  | 6PG |  |
| 516 | 1.2.11.5.2 | New system commissioning |  | 1w | 2015-01-05 | 2015-01-09 |  |  |  |  |  |  | 2002d |  |  |  |  |  | 10,000 |  | 6PG |  |
| 517 | 1.2.11.6 | **BE/ICS** |  | 10d | 2018-07-30 | 2018-08-10 |  |  |  | 2015-08-24 | 2015-09-21 | 0d | 1075d |  |  |  | 16h |  |  |  | 6L |  |
| 518 | 1.2.11.6.1 | New access control |  | 2w | 2018-07-30 | 2018-08-10 | 499 |  |  | 2015-08-24 | 2015-09-21 | 0d | 1075d | 0d |  | Nino Rama [20%] | 16h |  |  |  | 6L |  |
| 519 | 1.2.12 | **ISR 6 (storage area) RIGHT SIDE** |  | 776.5d | 2016-07-04 A | 2019-08-01 |  | 33% | 517.67d | 2015-06-18 | 2016-06-07 | 0d | 861.5d |  |  |  | 167.4h | 21h | 358,500 | 3,500 | 6R |  |
| 520 | 1.2.12.1 | ISR6 R Availability | milestone | 1d | 2017-01-09 | 2017-01-09 |  |  |  | 2015-06-29 | 2015-06-29 | 0d | 1513d |  | start no earlier than 2017-01-09 |  |  |  |  |  | 6R |  |
| 521 | 1.2.12.2 | **Civil engineering** |  | 653d | 2016-07-25 A | 2019-03-01 |  | 10% | 589.81d | 2016-02-03 | 2016-05-11 | 0d | 970d |  |  |  | 113.4h | 21h | 213,500 | 3,500 | 6R |  |
| 522 | 1.2.12.2.1 | Drainages sealing and waterproofing ? |  | 3w | 2016-12-01 | 2016-12-21 |  |  |  | 2016-02-17 | 2016-03-08 | 0d | 1516d |  | start no earlier than 2016-12-01 | Aurelien Benjamin Dodard [35%] | 42h |  | 60,000 |  | 6L |  |
| 523 | 1.2.12.2.2 | Floor waterproofing |  | 4w | 2019-02-04 | 2019-03-01 |  |  |  | 2015-07-13 | 2015-07-31 | 0d | 970d |  | start no earlier than 2019-02-04 | Aurelien Benjamin Dodard [35%] | 50.4h |  | 100,000 |  | 6L |  |
| 524 | 1.2.12.2.3 | Corbels repair |  | 1.5w | 2016-07-25 A | 2016-08-03 A | 482 | 100% |  | 2016-03-09 | 2016-03-31 | 0d |  |  |  | Aurelien Benjamin Dodard [35%] | 21h | 21h | 3,500 | 3,500 | 6R | Dimensione |
| 525 | 1.2.12.2.4 | Old fire wall dismounting |  | 3w | 2018-04-09 | 2018-04-27 | 306 |  |  |  |  |  | 1145d | 0d | start no earlier than 2017-05-15 |  |  |  | 10,000 |  | 6R |  |
| 526 | 1.2.12.2.5 | New fire wall & door |  | 4w | 2018-04-30 | 2018-05-25 | 525 |  |  |  |  |  | 1145d | 0d | start no earlier than 2017-05-15 |  |  |  | 40,000 |  | 6R |  |
| 527 | 1.2.12.3 | **Elec** |  | 171.5d | 2016-07-04 A | 2017-03-15 |  | 77% | 39.4d | 2016-05-10 | 2016-06-07 | 0d | 1466.5d |  |  |  |  |  |  |  | 6R |  |
| 528 | 1.2.12.3.1 | Commandes |  | 2w | 2016-07-04 A | 2016-07-15 A |  | 100% |  |  |  |  |  |  | start no earlier than 2016-07-04 |  |  |  |  |  | 6R |  |
| 529 | 1.2.12.3.2 | Installation drawings |  | 3w | 2016-07-18 A | 2016-08-05 A | 528 | 100% |  |  |  |  |  |  |  |  |  |  |  |  | 6R |  |
| 530 | 1.2.12.3.3 | Removals |  | 1.4w | 2016-10-03 A | 2016-10-11 |  | 50% | 0.7w |  |  |  | 1567d |  | start no earlier than 2016-10-03 |  |  |  |  |  | 6R |  |
| 531 | 1.2.12.3.4 | Decommission of CANALIS in the tunnel & other dismantling |  | 1w | 2017-03-08 | 2017-03-15 | 455 |  |  |  |  |  | 15d | 0d |  |  |  |  |  |  | 6R |  |

| ID | WBS | Task | Type | Duration | Start | Finish | Predecessors | Complete | Baseline start | Baseline finish | Baseline duration | Total slack | Free slack | Constraint | Resources | Work | Cost | Building | Contractor |
| --- | --- | --- | --- | --- | --- | --- | --- | --- | --- | --- | --- | --- | --- | --- | --- | --- | --- | --- | --- |
| 532 | 1.2.12.4 | **HVAC** |  | 12.5d | 2019-07-16 | 2019-08-01 |  |  | 2015-06-18 | 2016-03-15 | 0d | 773.5d |  |  |  | 30h | 125,000 | 6R |  |
| 533 | 1.2.12.4.1 | Tunnel works (fans, grids etc. including dry riser) |  | 2.5w | 2019-07-16 | 2019-08-01 | 491 |  | 2016-05-10 | 2016-05-17 | 0d | 773.5d | 0d |  | Franck Audinet [30%] | 30h | 125,000 | 6R | IT |
| 534 | 1.2.12.5 | **Fire detec.** |  | 10d | 2017-03-29 | 2017-04-12 |  |  | 2016-04-29 | 2016-05-09 | 0d | 1446.5d |  |  |  | 8h | 20,000 | 6R |  |
| 535 | 1.2.12.5.1 | Old system dismantling & new system |  | 1w | 2017-03-29 | 2017-04-05 | 515 |  |  |  |  | 1446.5d | 0d |  |  |  |  | 6R |  |
| 536 | 1.2.12.5.2 | New system commissioning |  | 1w | 2017-04-05 | 2017-04-12 | 535 |  | 2016-04-29 | 2016-05-09 | 0d | 1446.5d |  |  | Denis Raffourt [20%] | 8h | 20,000 | 6R |  |
| 537 | 1.2.12.6 | **BE/ICS** |  | 10d | 2018-08-13 | 2018-08-24 |  |  | 2015-08-24 | 2015-09-21 | 0d | 1075d |  |  |  | 16h |  | 6R |  |
| 538 | 1.2.12.6.1 | New access control |  | 2w | 2018-08-13 | 2018-08-24 | 500, 518 |  | 2015-08-24 | 2015-09-21 | 0d | 1075d | 0d |  | Nino Rama [20%] | 16h |  | 6R |  |
| 539 | 1.2.12.7 | **EN/HE** |  | 20d | 2016-12-05 A | 2017-01-13 A |  | 100% | 2016-02-03 | 2016-03-01 | 0d |  |  |  |  |  |  | 6R |  |
| 540 | 1.2.12.7.1 | Shielding zone modification |  | 4w | 2016-12-05 A | 2017-01-13 A |  | 100% |  |  |  |  |  | start no earlier than 2016-12-05 |  |  |  | 6R |  |
| 542 | 1.2.13 | **ISR 7 (storage area) LEFT SIDE - INTERNAL WALL ONLY** |  | 736d | 2018-06-25 | 2021-04-19 |  |  | 2015-06-18 | 2016-06-07 | 0d | 414d |  |  |  | 241.6h | 589,000 | 7L |  |
| 543 | 1.2.13.1 | ISR7 L Availability | milestone | 1d | 2020-01-13 | 2020-01-13 |  |  | 2015-06-29 | 2015-06-29 | 0d | 674d | 0d | start no earlier than 2020-01-13 |  |  |  | 7L |  |
| 544 | 1.2.13.2 | **Civil engineering** |  | 476d | 2018-06-25 | 2020-04-20 |  |  | 2016-02-03 | 2016-05-11 | 0d | 674d |  |  |  | 140.4h | 343,000 | 7L |  |
| 545 | 1.2.13.2.1 | Floor repair (metal rails) |  | 1w | 2020-01-14 | 2020-01-20 | 543 |  | 2015-08-03 | 2015-08-07 | 0d | 729d | 0d | start no earlier than 2018-03-12 | Aurelien Benjamin Dodard [35%] | 20h | 5,000 | 7L | Dimensione |
| 546 | 1.2.13.2.2 | Drainages and holes sealing |  | 2w | 2020-01-21 | 2020-02-03 | 545 |  | 2015-08-03 | 2015-08-07 | 0d | 729d |  | start no earlier than 2018-03-12 | Aurelien Benjamin Dodard [35%] | 28h | 40,000 | 7L | Dimensione |
| 547 | 1.2.13.2.3 | Floor waterproofing |  | 4w | 2020-03-24 | 2020-04-20 | 554 |  | 2015-07-13 | 2015-07-31 | 0d | 674d |  | start no earlier than 2018-07-02 | Aurelien Benjamin Dodard [35%] | 50.4h | 220,000 | 7L |  |
| 548 | 1.2.13.2.4 | Painting 1st phase |  | 1w | 2020-02-04 | 2020-02-10 | 553 |  | 2015-09-07 | 2015-09-29 | 0d | 724d |  |  | Aurelien Benjamin Dodard [35%] | 14h | 28,000 | 7L | Prezioso |
| 549 | 1.2.13.2.5 | Painting 2 nd phase |  | 1w | 2020-03-24 | 2020-03-30 | 554 |  | 2015-09-07 | 2015-09-29 | 0d | 689d |  |  | Aurelien Benjamin Dodard [35%] | 14h |  | 7L | Prezioso |
| 550 | 1.2.13.2.6 | Sealing holes, walls and existing doors (fire) |  | 1w | 2018-06-25 | 2018-06-29 | 569 |  | 2015-09-07 | 2015-09-29 | 0d | 1145d |  |  | Aurelien Benjamin Dodard [35%] | 14h | 35,000 | 7L |  |
| 551 | 1.2.13.2.7 | Civil eng works for HVAC |  | 3w | 2018-10-30 | 2018-11-19 | 483 |  |  |  |  | 1044d |  |  |  |  | 15,000 | 7L |  |
| 552 | 1.2.13.3 | **Elec** |  | 295d | 2020-01-14 | 2021-03-01 |  |  | 2016-05-10 | 2016-06-07 | 0d | 449d |  |  |  | 24h | 80,000 | 7L |  |
| 553 | 1.2.13.3.1 | Removals |  | 3w | 2020-01-14 | 2020-02-03 | 543 |  |  |  |  | 674d | 0d |  |  |  | 10,000 | 7L |  |
| 554 | 1.2.13.3.2 | Installations |  | 7w | 2020-02-04 | 2020-03-23 | 553 |  |  |  |  | 674d | 0d |  |  |  | 70,000 | 7L |  |
| 555 | 1.2.13.3.3 | Partial acceptance and inspection |  | 1w | 2021-02-23 | 2021-03-01 | 556 |  | 2016-06-08 | 2016-06-14 | 0d | 449d |  |  | Miriam Munoz Codoceo [30%] | 12h |  | 7L |  |
| 556 | 1.2.13.3.4 | Decommission of CANALIS in the tunnel & other dismantling |  | 1w | 2021-02-16 | 2021-02-22 | 610 |  | 2016-06-08 | 2016-06-14 | 0d | 449d | 0d |  | Miriam Munoz Codoceo [30%] | 12h |  | 7L |  |

| ID | WBS | Task | Type | Duration | Start | Finish | Predecessors | Complete | Remaining | Baseline start | Baseline finish | Baseline duration | Total slack | Free slack | Constraint | Resources | Work | Actual work | Cost | Actual cost | Building | Contractor |
| --- | --- | --- | --- | --- | --- | --- | --- | --- | --- | --- | --- | --- | --- | --- | --- | --- | --- | --- | --- | --- | --- | --- |
| 557 | 1.2.13.4 | **HVAC** |  | 452d | 2019-05-16 | 2021-02-05 |  |  |  | 2015-06-18 | 2016-03-15 | 0d | 465d |  |  |  | 37.2h |  | 146,000 |  | 7L |  |
| 558 | 1.2.13.4.1 | Ducts dismantling |  | 3d | 2021-02-02 | 2021-02-04 | 580 |  |  | 2015-06-18 | 2015-06-24 | 0d | 460d | 0d |  | Franck Audinet [30%] | 7.2h |  | 20,000 |  | 7L | Dalkia |
| 559 | 1.2.13.4.2 | Old gas pipe dismounting |  | 1d | 2021-02-05 | 2021-02-05 | 558 |  |  |  |  |  | 465d |  |  |  |  |  | 1,000 |  | 7L |  |
| 560 | 1.2.13.4.3 | Tunnel works (fans, grids etc. including hose reels) |  | 2.5w | 2019-05-16 | 2019-06-03 | 588 |  |  | 2016-05-10 | 2016-05-17 | 0d | 773.5d | 0d |  | Franck Audinet [30%] | 30h |  | 125,000 |  | 7L | IT |
| 561 | 1.2.13.5 | **Fire detec.** |  | 20d | 2021-03-23 | 2021-04-19 |  |  |  | 2016-04-29 | 2016-05-09 | 0d | 414d |  |  |  | 24h |  | 20,000 |  | 7L |  |
| 562 | 1.2.13.5.1 | Old system dismantling & new system |  | 1w | 2021-03-23 | 2021-03-29 | 581 |  |  |  |  |  | 414d | 0d |  |  |  |  |  |  | 7L |  |
| 563 | 1.2.13.5.2 | New system commissioning |  | 3w | 2021-03-30 | 2021-04-19 | 562 |  |  | 2016-04-29 | 2016-05-09 | 0d | 414d |  |  | Denis Raffourt [20%] | 24h |  | 20,000 |  | 7L |  |
| 564 | 1.2.13.6 | **BE/ICS** |  | 10d | 2018-08-27 | 2018-09-07 |  |  |  | 2015-08-24 | 2015-09-21 | 0d | 1075d |  |  |  | 16h |  |  |  | 7L |  |
| 565 | 1.2.13.6.1 | New access control |  | 2w | 2018-08-27 | 2018-09-07 | 538 |  |  | 2015-08-24 | 2015-09-21 | 0d | 1075d | 0d |  | Nino Rama [20%] | 16h |  |  |  | 7L |  |
| 566 | 1.2.14 | **ISR 7 (storage area) RIGHT SIDE** |  | 1494d | 2015-05-29 A | 2021-04-19 |  | 10% | 1344.88d | 2015-04-13 | 2016-07-26 | 0d | 414d |  |  |  | 509.2h | 111.8h | 668,500 | 56,500 | 7L |  |
| 567 | 1.2.14.1 | ISR7 R Availability | milestone | 1d | 2021-01-11 | 2021-01-11 |  |  |  | 2015-09-07 | 2015-09-07 | 0d | 414d | 0d | start no earlier than 2021-01-11 |  |  |  |  |  | 7R |  |
| 568 | 1.2.14.2 | **Civil engineering** |  | 1402d | 2015-10-07 A | 2021-04-19 |  | 6% | 1324.11d | 2015-11-25 | 2016-04-07 | 0d | 414d |  |  |  | 171.2h | 12.6h | 358,500 | 22,500 | 7R |  |
| 569 | 1.2.14.2.1 | New fire wall & door |  | 4w | 2018-05-28 | 2018-06-22 | 526 |  |  |  |  |  | 1145d | 0d | start no earlier than 2017-05-15 |  |  |  | 30,000 |  | 7R |  |
| 570 | 1.2.14.2.2 | Floor repair (metal rails) |  | 1w | 2021-01-12 | 2021-01-18 | 567 |  |  | 2015-08-03 | 2015-08-07 | 0d | 469d | 0d | start no earlier than 2018-03-12 | Aurelien Benjamin Dodard [35%] | 20h |  | 5,000 |  | 7R | Dimensione |
| 571 | 1.2.14.2.3 | Drainages and holes sealing |  | 2w | 2021-01-19 | 2021-02-01 | 570 |  |  | 2015-08-03 | 2015-08-07 | 0d | 469d |  | start no earlier than 2018-03-12 | Aurelien Benjamin Dodard [35%] | 28h |  | 20,000 |  | 7R | Dimensione |
| 572 | 1.2.14.2.4 | Floor waterproofing |  | 4w | 2021-03-23 | 2021-04-19 | 581 |  |  | 2015-07-13 | 2015-07-31 | 0d | 414d |  | start no earlier than 2018-07-02 | Aurelien Benjamin Dodard [35%] | 50.4h |  | 220,000 |  | 7R |  |
| 573 | 1.2.14.2.5 | Painting 1st phase |  | 1w | 2021-02-02 | 2021-02-08 | 580 |  |  | 2015-09-07 | 2015-09-29 | 0d | 464d |  |  | Aurelien Benjamin Dodard [35%] | 14h |  | 28,000 |  | 7R | Prezioso |
| 574 | 1.2.14.2.6 | Painting 2 nd phase |  | 1w | 2021-03-23 | 2021-03-29 | 581 |  |  | 2015-09-07 | 2015-09-29 | 0d | 429d |  |  | Aurelien Benjamin Dodard [35%] | 14h |  |  |  | 7R | Prezioso |
| 575 | 1.2.14.2.7 | New door for ventil incl. fire boxes |  | 3d | 2017-04-03 A | 2017-04-05 | 480 | 50% | 1.5d |  |  |  | 2.25d | 0d |  | Aurelien Benjamin Dodard [35%] | 8.4h | 4.2h | 36,000 | 18,000 | 7R | Poralu |
| 576 | 1.2.14.2.8 | Grid and gutter repair (including drying) |  | 3d | 2015-10-07 A | 2015-10-09 A | 481 | 100% |  |  |  |  |  |  |  | Aurelien Benjamin Dodard [35%] | 8.4h | 8.4h | 4,500 | 4,500 | 7R | Scrasa |
| 577 | 1.2.14.2.9 | Stairs replacement (ISR8) |  | 1w | 2018-04-16 | 2018-04-20 | 148 |  |  |  |  |  | 1195d |  |  | Aurelien Benjamin Dodard [35%] | 14h |  | 10,000 |  | 7R |  |
| 578 | 1.2.14.2.10 | Door replacement (between ISR 7 and ISR8) |  | 1w | 2018-06-25 | 2018-06-29 | 569 |  |  | 2015-09-07 | 2015-09-29 | 0d | 1145d |  |  | Aurelien Benjamin Dodard [35%] | 14h |  | 5,000 |  | 7R |  |
| 579 | 1.2.14.3 | **Elec** |  | 50d | 2021-01-12 | 2021-03-22 |  |  |  | 2016-06-08 | 2016-07-12 | 0d | 414d |  |  |  |  |  | 80,000 |  | 7R |  |
| 580 | 1.2.14.3.1 | Removals |  | 3w | 2021-01-12 | 2021-02-01 | 567 |  |  |  |  |  | 414d | 0d |  |  |  |  | 10,000 |  | 7R |  |
| 581 | 1.2.14.3.2 | Installations |  | 7w | 2021-02-02 | 2021-03-22 | 580 |  |  |  |  |  | 414d | 0d |  |  |  |  | 70,000 |  | 7R |  |

| ID | WBS | Task | Type | Duration | Start | Finish | Predecessors | Complete | Remaining | Baseline start | Baseline finish | Baseline duration | Total slack | Free slack | Constraint | Resources | Work | Actual work | Cost | Actual cost | Building | Contractor |
| --- | --- | --- | --- | --- | --- | --- | --- | --- | --- | --- | --- | --- | --- | --- | --- | --- | --- | --- | --- | --- | --- | --- |
| 582 | 1.2.14.4 | **HVAC** |  | 1448d | 2015-05-29 A | 2021-02-12 |  | 20% | 1154.4d | 2015-04-13 | 2016-07-26 | 0d | 460d |  |  |  | 306h | 99.2h | 188,000 | 34,000 | 7R |  |
| 583 | 1.2.14.4.1 | Asbestos diag (campagne) |  | 2w | 2015-05-29 A | 2015-06-11 A |  | 100% |  | 2015-04-13 | 2015-05-27 | 0d |  |  | start no earlier than 2015-05-29 | HSE/SEE | 80h | 80h |  |  | 7R |  |
| 584 | 1.2.14.4.2 | Ventil units dismantling V7 |  | 12d | 2016-04-04 A | 2016-04-19 A | 489 | 100% |  | 2016-07-20 | 2016-07-26 | 0d |  |  |  | Aurelien Benjamin Dodard [20%] | 19.2h | 19.2h | 34,000 | 34,000 | 7R | Altead, Ram Power |
| 585 | 1.2.14.4.3 | Ducts dismantling |  | 1w | 2021-02-05 | 2021-02-11 | 558 |  |  | 2015-06-25 | 2015-07-01 | 0d | 460d | 0d |  | Franck Audinet [30%] | 12h |  | 3,000 |  | 7R | Dalkia |
| 586 | 1.2.14.4.4 | Old gas pipe dismounting |  | 1d | 2021-02-12 | 2021-02-12 | 585 |  |  |  |  |  | 460d |  |  | Aurelien Benjamin Dodard [20%] | 1.6h |  | 1,000 |  | 7R |  |
| 587 | 1.2.14.4.5 | Underground galleries works (dry raiser) |  | 5w | 2019-04-08 | 2019-05-13 | 205 |  |  | 2016-04-29 | 2016-05-09 | 1w | 773.5d | 0d |  | Franck Audinet [30%] | 60h |  | 25,000 |  | 7R | IT |
| 588 | 1.2.14.4.6 | Tunnel works (fans, grids etc. including dry riser) |  | 2.5w | 2019-04-29 | 2019-05-15 | 589SS |  |  | 2016-05-10 | 2016-05-17 | 0d | 773.5d | 0d |  | Franck Audinet [30%] | 30h |  |  |  | 7R | IT |
| 589 | 1.2.14.4.7 | Ventilation room (over the tunnel) works |  | 4w | 2019-04-29 | 2019-05-27 | 587SS+3w |  |  | 2016-05-18 | 2016-05-24 | 0d | 773.5d | 0d |  | Franck Audinet [30%] | 48h |  | 125,000 |  | 7R | IT |
| 590 | 1.2.14.4.8 | Works outside (surface - above ventil room) |  | 4w | 2019-04-08 | 2019-05-06 | 587SS |  |  | 2016-05-18 | 2016-05-24 | 0d | 924.5d |  |  | Franck Audinet [30%] | 48h |  |  |  | 7R | IT |
| 591 | 1.2.14.4.9 | Partial acceptance and inspection ISR7 only |  | 3d | 2019-06-03 | 2019-06-06 | 560 |  |  | 2016-06-08 | 2016-06-14 | 0d | 773.5d | 0d |  | Franck Audinet [30%] | 7.2h |  |  |  | 7R |  |
| 592 | 1.2.14.5 | **Fire detec.** |  | 10d | 2021-03-30 | 2021-04-12 |  |  |  | 2016-05-18 | 2016-05-31 | 0d | 414d |  |  |  | 16h |  | 20,000 |  | 7R |  |
| 593 | 1.2.14.5.1 | Old system dismantling & new system |  | 1w | 2021-03-30 | 2021-04-05 | 562 |  |  | 2016-05-18 | 2016-05-24 | 0d | 414d | 0d |  | Denis Raffourt [20%] | 8h |  |  |  | 7R |  |
| 594 | 1.2.14.5.2 | New system commissioning |  | 1w | 2021-04-06 | 2021-04-12 | 593 |  |  | 2016-05-25 | 2016-05-31 | 0d | 419d |  |  | Denis Raffourt [20%] | 8h |  | 20,000 |  | 7R |  |
| 595 | 1.2.14.6 | **IT/CS** |  | 5d | 2017-03-13 | 2017-03-17 |  |  |  | 2016-07-13 | 2016-07-14 | 0d | 1464d |  |  |  |  |  | 22,000 |  | 7R |  |
| 596 | 1.2.14.6.1 | New cable and antenna (fixation on cables trays) |  | 1w | 2017-03-13 | 2017-03-17 |  |  |  | 2016-07-13 | 2016-07-14 | 0d | 1464d |  | start no earlier than 2017-03-13 |  |  |  | 22,000 |  | 7R |  |
| 597 | 1.2.14.7 | **BE/ICS** |  | 10d | 2018-09-10 | 2018-09-21 |  |  |  | 2015-09-22 | 2015-10-19 | 0d | 1075d |  |  |  | 16h |  |  |  | 7R |  |
| 598 | 1.2.14.7.1 | New access control |  | 2w | 2018-09-10 | 2018-09-21 | 565 |  |  | 2015-09-22 | 2015-10-19 | 0d | 1075d | 0d |  | Nino Rama [20%] | 16h |  |  |  | 7R |  |
| 599 | 1.2.15 | **T7 parallel gallery** |  | 1040d | 2017-04-03 A | 2021-04-19 |  | 29% | 739.38d | 2015-09-07 | 2016-06-07 | 0d | 414d |  |  |  | 201.6h | 61.6h | 190,000 | 135,000 | 7PG |  |
| 600 | 1.2.15.1 | T7 Availability | milestone | 1d | 2021-01-11 | 2021-01-11 | 567SS |  |  | 2015-09-07 | 2015-09-07 | 0d | 484d |  |  |  |  |  |  |  | 7PG |  |
| 601 | 1.2.15.2 | **Civil engineering** |  | 549.5d | 2017-04-03 A | 2019-06-03 |  | 65% | 192.81d |  |  |  | 904.5d |  |  |  | 77.6h | 61.6h | 180,000 | 135,000 | 7PG |  |
| 602 | 1.2.15.2.1 | Metallic structure dismanteling in ISR8L + services modification |  | 3w | 2017-04-03 A | 2017-08-25 A |  | 100% |  |  |  |  |  |  | start no earlier than 2017-04-03 |  |  |  | 35,000 | 35,000 | 7PG |  |
| 603 | 1.2.15.2.2 | Waterproofing underground galleries |  | 12d | 2017-04-21 A | 2017-05-09 A | 281 | 100% |  | 2016-02-03 | 2016-02-16 | 0d |  |  |  | Aurelien Benjamin Dodard [35%] | 33.6h | 33.6h | 60,000 | 60,000 | 7PG |  |
| 604 | 1.2.15.2.3 | Waterproofing ISR8L, slab and walls |  | 2w | 2017-06-15 A | 2017-06-28 A | 504 | 100% |  | 2016-02-03 | 2016-02-16 | 0d |  |  |  | Aurelien Benjamin Dodard [35%] | 28h | 28h | 40,000 | 40,000 | 7PG |  |
| 605 | 1.2.15.2.4 | Doors for access control |  | 1w | 2018-04-23 | 2018-04-27 | 607 |  |  |  |  |  | 1190d |  |  | Aurelien Benjamin Dodard [20%] | 8h |  | 15,000 |  | 7PG |  |
| 606 | 1.2.15.2.5 | Filling holes between gallerie and tunnel |  | 1w | 2019-05-27 | 2019-06-03 | 612 |  |  |  |  |  | 904.5d |  |  | Aurelien Benjamin Dodard [20%] | 8h |  | 5,000 |  | 7PG |  |
| 607 | 1.2.15.2.6 | Fire walls |  | 2w | 2018-04-09 | 2018-04-20 | 306 |  |  |  |  |  | 1190d | 0d |  |  |  |  | 25,000 |  | 7PG |  |

| ID | WBS | Task | Duration | Start | Finish | Predecessors | Baseline start | Baseline finish | Baseline duration | Total slack | Free slack | Constraint | Resources | Work | Cost | Building | Contractor |
| --- | --- | --- | --- | --- | --- | --- | --- | --- | --- | --- | --- | --- | --- | --- | --- | --- | --- |
| 608 | 1.2.15.3 | **Elec** | 10d | 2021-02-02 | 2021-02-15 |  |  |  |  | 449d |  |  |  | 12h |  | 7PG |  |
| 609 | 1.2.15.3.1 | Installation of new cable trays | 1w | 2021-02-02 | 2021-02-08 | 580 |  |  |  | 449d | 0d | start no earlier than 2016-11-28 |  |  |  | 7PG |  |
| 610 | 1.2.15.3.2 | Cabling & lighting | 1w | 2021-02-09 | 2021-02-15 | 609 |  |  |  | 449d | 0d |  | Miriam Munoz Codoceo [30%] | 12h |  | 7PG |  |
| 611 | 1.2.15.4 | **HVAC** | 35d | 2019-04-08 | 2019-05-27 |  | 2016-04-08 | 2016-04-21 | 0d | 909.5d |  |  |  | 96h |  | 7PG |  |
| 612 | 1.2.15.4.1 | Gallery works (ducts, grids etc.) | 4w | 2019-04-29 | 2019-05-27 | 588SS | 2016-05-10 | 2016-05-17 | 0d | 904.5d | 0d |  | Franck Audinet [30%] | 48h |  | 7PG | IT |
| 613 | 1.2.15.4.2 | Works outside (surface) | 4w | 2019-04-08 | 2019-05-06 | 587SS | 2016-05-18 | 2016-05-24 | 0d | 924.5d |  |  | Franck Audinet [30%] | 48h |  | 7PG | IT |
| 614 | 1.2.15.5 | **Fire detec.** | 10d | 2021-04-06 | 2021-04-19 |  | 2016-06-01 | 2016-06-07 | 0d | 414d |  |  |  |  | 10,000 | 7PG |  |
| 615 | 1.2.15.5.1 | Old system dismantling & new system | 1w | 2021-04-06 | 2021-04-12 | 593 | 2016-06-01 | 2016-06-07 | 0d | 414d | 0d |  |  |  |  | 7PG |  |
| 616 | 1.2.15.5.2 | New system commissioning | 1w | 2021-04-13 | 2021-04-19 | 615 |  |  |  | 414d |  |  |  |  | 10,000 | 7PG |  |
| 617 | 1.2.15.6 | **BE/ICS** | 10d | 2018-09-24 | 2018-10-05 |  | 2015-09-22 | 2015-10-19 | 0d | 1075d |  |  |  | 16h |  | 7R |  |
| 618 | 1.2.15.6.1 | New access control | 2w | 2018-09-24 | 2018-10-05 | 598 | 2015-09-22 | 2015-10-19 | 0d | 1075d |  |  | Nino Rama [20%] | 16h |  | 7R |  |
